# MSF Application Development

Schedule from MS Project, 2004-01-01 to 2005-02-16.

## Calendars

- Standard: Mon-Fri 08:00-12:00, 13:00-17:00; Sat-Sun off.

## Resources

| Resource |
| --- |
| Program management |
| Product management |
| Development |
| Testing |
| Logistics management |
| User education |
| Support organization |
| Customer |

## Schedule

| ID | WBS | Task | Type | Duration | Start | Finish | Predecessors | Baseline start | Baseline finish | Baseline duration | Total slack | Free slack | Resources | Work | Text4 |
| --- | --- | --- | --- | --- | --- | --- | --- | --- | --- | --- | --- | --- | --- | --- | --- |
| 1 | 1 | **Project Kick-Off** |  | 6d | 2004-01-01 | 2004-01-08 |  | 2004-01-01 | 2004-01-08 | 6d | 0d |  | Product management | 368h | {B037AD26-031F-4224-B2A3-7583F40A4A7A} |
| 2 | 1.1 | **Form Team** |  | 6d | 2004-01-01 | 2004-01-08 |  | 2004-01-01 | 2004-01-08 | 6d | 0d |  |  | 320h | {52124130-3814-42B9-A7A9-EACD5473856F} |
| 3 | 1.1.1 | Define team roles |  | 2d | 2004-01-01 | 2004-01-02 |  | 2004-01-01 | 2004-01-02 | 2d | 0d |  | Program management; Product management; Development; Testing; Logistics management | 80h | {77A309CE-D049-4238-925C-69FA8F56AACD} |
| 4 | 1.1.2 | Identify required skills |  | 2d | 2004-01-01 | 2004-01-02 |  | 2004-01-01 | 2004-01-02 | 2d | 0d |  | Program management; Product management; Development; Testing; Logistics management | 80h | {182EB7E0-7E8F-4360-8F2A-B0473A29A221} |
| 5 | 1.1.3 | Identify resources |  | 2d | 2004-01-05 | 2004-01-06 | 4, 3 | 2004-01-05 | 2004-01-06 | 2d | 0d |  | Program management; Product management; Development; Testing; Logistics management | 80h | {CC5C8E3F-9CA5-4519-93FE-1209E21BA96B} |
| 6 | 1.1.4 | Assign roles to resources |  | 2d | 2004-01-07 | 2004-01-08 | 5 | 2004-01-07 | 2004-01-08 | 2d | 0d |  | Program management; Product management; Development; Testing; Logistics management | 80h | {DB1A5533-6CF4-4B3E-A412-07A48A5E8CE9} |
| 7 | 1.1.5 | Team formed | milestone | 0d | 2004-01-08 | 2004-01-08 | 6 | 2004-01-08 | 2004-01-08 | 0d | 0d |  |  |  | {A6808068-3CE5-4163-B387-71DFB465B522} |
| 8 | 2 | **Envisioning** |  | 44d | 2004-01-09 | 2004-03-10 | 7 | 2004-01-09 | 2004-03-10 | 44d | 0d |  | Product management | 1222.4h | {5385B884-11D3-461C-B887-B5B2CF01A321} |
| 9 | 2.1 | Define preliminary business requirements (ongoing) |  | 29d | 2004-01-09 | 2004-02-18 | 7 | 2004-01-09 | 2004-02-18 | 29d | 260d |  | Product management [50%]; Program management [20%] | 162.4h | {7E3A2F2C-F01A-4E7A-8A1C-D13117E827B0} |
| 10 | 2.2 | Risk management |  | 1d | 2004-01-09 | 2004-01-09 | 7 | 2004-01-09 | 2004-01-09 | 1d | 43d |  |  |  | {DD98A7AE-EAB9-46D1-AD01-9670EBE5E3DE} |
| 11 | 2.3 | **Define Project Structure** |  | 9d | 2004-01-09 | 2004-01-21 | 7 | 2004-01-09 | 2004-01-21 | 9d | 35d |  |  | 156h | {770A8AEC-AE7F-4D06-BB73-301EA92CD82D} |
| 12 | 2.3.1 | Define project tracking process |  | 5d | 2004-01-09 | 2004-01-15 |  | 2004-01-09 | 2004-01-15 | 5d | 39d | 4d | Program management [25%]; Product management [25%]; User education [25%]; Testing [25%]; Development [25%]; Logistics management [25%] | 60h | {58891831-190D-46C3-8591-7EF81373AD93} |
| 13 | 2.3.2 | Define problem resolution process |  | 4d | 2004-01-09 | 2004-01-14 |  | 2004-01-09 | 2004-01-14 | 4d | 40d | 5d | Program management [25%]; Development [25%]; Testing [25%] | 24h | {0A250DFC-42A0-437B-99A8-A8265109A483} |
| 14 | 2.3.3 | Define issue tracking process |  | 3d | 2004-01-09 | 2004-01-13 |  | 2004-01-09 | 2004-01-13 | 3d | 35d | 0d | Development [25%]; Testing [25%]; Program management [50%] | 24h | {0FFE95B1-039D-4073-9BDB-A844B54516C5} |
| 15 | 2.3.4 | Define change control procedures |  | 4d | 2004-01-14 | 2004-01-19 | 14 | 2004-01-14 | 2004-01-19 | 4d | 35d | 0d | Testing [25%]; Program management [25%]; Development [25%]; Product management [25%] | 32h | {FF722132-8994-402C-93FA-73F39A49B40D} |
| 16 | 2.3.5 | Define accountability and expectations |  | 2d | 2004-01-20 | 2004-01-21 | 15 | 2004-01-20 | 2004-01-21 | 2d | 35d | 0d | Program management [50%]; Product management [50%] | 16h | {C41684D2-5067-402C-8309-4158407C284E} |
| 17 | 2.3.6 | Project structure determined | milestone | 0d | 2004-01-21 | 2004-01-21 | 12, 13, 16 | 2004-01-21 | 2004-01-21 | 0d | 35d |  |  |  | {58CABF62-3F61-4F99-B886-C378758B050C} |
| 18 | 2.4 | **Research and Gather Assumptions** |  | 25d | 2004-01-09 | 2004-02-12 |  | 2004-01-09 | 2004-02-12 | 25d | 0d |  |  | 208h | {62DCBF95-503D-4E9E-898B-D6C13F7C3D43} |
| 19 | 2.4.1 | Conduct preliminary user interviews |  | 2d | 2004-01-09 | 2004-01-12 |  | 2004-01-09 | 2004-01-12 | 2d | 0d |  | Product management; Program management; Development | 48h | {680818D2-0D0A-4194-87C5-D5C420D8DB31} |
| 20 | 2.4.2 | Define usage scenarios |  | 10d | 2004-01-13 | 2004-01-26 | 19 | 2004-01-13 | 2004-01-26 | 10d | 0d |  | Product management [25%]; Development [25%]; Program management [25%] | 60h | {E16A104F-6E3B-4CBB-8660-378C8DEAED01} |
| 21 | 2.4.3 | Develop preliminary user profile |  | 5d | 2004-01-27 | 2004-02-02 | 20 | 2004-01-27 | 2004-02-02 | 5d | 2d | 0d | Product management [25%]; User education [25%] | 20h | {D02F746A-244A-4C2E-AB2C-BF197EC09E55} |
| 22 | 2.4.4 | Develop preliminary vision statement |  | 1d | 2004-02-03 | 2004-02-03 | 21 | 2004-02-03 | 2004-02-03 | 1d | 2d |  | Product management [25%] | 2h | {7FB68887-E502-42FC-BD06-73A2FAD70EFC} |
| 23 | 2.4.5 | Establish design goals |  | 8d | 2004-01-27 | 2004-02-05 | 20 | 2004-01-27 | 2004-02-05 | 8d | 0d |  | Product management [25%]; Program management [25%]; Development [25%] | 48h | {208B246B-864F-4DCD-BD0C-3D34AB820E2C} |
| 24 | 2.4.6 | Develop preliminary solution concept |  | 5d | 2004-02-06 | 2004-02-12 | 23, 22 | 2004-02-06 | 2004-02-12 | 5d | 0d |  | Program management [25%]; Customer [25%]; Development [25%] | 30h | {C5B4A003-C2FB-4F48-B0EA-F0038D9C7A82} |

Notes:
- 1: Text3: <sync-guid>{B037AD26-031F-4224-B2A3-7583F40A4A7A}</sync-guid><sync-parentguid>{7132D1D4-D456-4D63-BFC8-4726AD2508E4}</sync-parentguid><sync-checksum>1840770934</sync-checksum><sync-rootid>0</sync-rootid><sync-itemtype>0</sync-itemtype><sync-timestamp>2003 / Text5: -04-27 18:54:30</sync-timestamp><sync-itemid>1</sync-itemid><sync-prioritymapping>0:0-0/1:700-1000/2:300-699/3:1-299</sync-prioritymapping>
- 2: Text3: <sync-guid>{52124130-3814-42B9-A7A9-EACD5473856F}</sync-guid><sync-parentguid>{B037AD26-031F-4224-B2A3-7583F40A4A7A}</sync-parentguid><sync-checksum>560998458</sync-checksum><sync-rootid>0</sync-rootid><sync-itemtype>0</sync-itemtype><sync-timestamp>2003- / Text5: 04-27 18:54:31</sync-timestamp><sync-itemid>2</sync-itemid><sync-prioritymapping>0:0-0/1:700-1000/2:300-699/3:1-299</sync-prioritymapping>
- 3: Text3: <sync-guid>{77A309CE-D049-4238-925C-69FA8F56AACD}</sync-guid><sync-parentguid>{52124130-3814-42B9-A7A9-EACD5473856F}</sync-parentguid><sync-checksum>-1816503078</sync-checksum><sync-rootid>0</sync-rootid><sync-itemtype>0</sync-itemtype><sync-timestamp>200 / Text5: 3-04-27 18:54:31</sync-timestamp><sync-itemid>3</sync-itemid><sync-prioritymapping>0:0-0/1:700-1000/2:300-699/3:1-299</sync-prioritymapping>
- 4: Text3: <sync-guid>{182EB7E0-7E8F-4360-8F2A-B0473A29A221}</sync-guid><sync-parentguid>{52124130-3814-42B9-A7A9-EACD5473856F}</sync-parentguid><sync-checksum>-187173780</sync-checksum><sync-rootid>0</sync-rootid><sync-itemtype>0</sync-itemtype><sync-timestamp>2003 / Text5: -04-27 18:54:31</sync-timestamp><sync-itemid>4</sync-itemid><sync-prioritymapping>0:0-0/1:700-1000/2:300-699/3:1-299</sync-prioritymapping>
- 5: Text3: <sync-guid>{CC5C8E3F-9CA5-4519-93FE-1209E21BA96B}</sync-guid><sync-parentguid>{52124130-3814-42B9-A7A9-EACD5473856F}</sync-parentguid><sync-checksum>-1636882410</sync-checksum><sync-rootid>0</sync-rootid><sync-itemtype>0</sync-itemtype><sync-timestamp>200 / Text5: 3-04-27 18:54:32</sync-timestamp><sync-itemid>5</sync-itemid><sync-prioritymapping>0:0-0/1:700-1000/2:300-699/3:1-299</sync-prioritymapping>
- 6: Text3: <sync-guid>{DB1A5533-6CF4-4B3E-A412-07A48A5E8CE9}</sync-guid><sync-parentguid>{52124130-3814-42B9-A7A9-EACD5473856F}</sync-parentguid><sync-checksum>-478019959</sync-checksum><sync-rootid>0</sync-rootid><sync-itemtype>0</sync-itemtype><sync-timestamp>2003 / Text5: -04-27 18:54:32</sync-timestamp><sync-itemid>6</sync-itemid><sync-prioritymapping>0:0-0/1:700-1000/2:300-699/3:1-299</sync-prioritymapping>
- 7: Text3: <sync-guid>{A6808068-3CE5-4163-B387-71DFB465B522}</sync-guid><sync-parentguid>{52124130-3814-42B9-A7A9-EACD5473856F}</sync-parentguid><sync-checksum>-1902231291</sync-checksum><sync-rootid>0</sync-rootid><sync-itemtype>0</sync-itemtype><sync-timestamp>200 / Text5: 3-04-27 18:54:32</sync-timestamp><sync-itemid>7</sync-itemid><sync-prioritymapping>0:0-0/1:700-1000/2:300-699/3:1-299</sync-prioritymapping>
- 8: Text3: <sync-guid>{5385B884-11D3-461C-B887-B5B2CF01A321}</sync-guid><sync-parentguid>{7132D1D4-D456-4D63-BFC8-4726AD2508E4}</sync-parentguid><sync-checksum>-897857265</sync-checksum><sync-rootid>0</sync-rootid><sync-itemtype>0</sync-itemtype><sync-timestamp>2003 / Text5: -04-27 18:54:33</sync-timestamp><sync-itemid>8</sync-itemid><sync-prioritymapping>0:0-0/1:700-1000/2:300-699/3:1-299</sync-prioritymapping>
- 9: Text3: <sync-guid>{7E3A2F2C-F01A-4E7A-8A1C-D13117E827B0}</sync-guid><sync-parentguid>{5385B884-11D3-461C-B887-B5B2CF01A321}</sync-parentguid><sync-checksum>280271229</sync-checksum><sync-rootid>0</sync-rootid><sync-itemtype>0</sync-itemtype><sync-timestamp>2003- / Text5: 04-27 18:54:33</sync-timestamp><sync-itemid>9</sync-itemid><sync-prioritymapping>0:0-0/1:700-1000/2:300-699/3:1-299</sync-prioritymapping>
- 10: This task should continue to occur throughout the Envisioning phase. One way to represent this is to do a paste link from the start date of task 12 to the start date of this task, and then do a paste link from the finish date of 34 to the finish date of this task. See the template Help file for more details. / Text3: <sync-guid>{DD98A7AE-EAB9-46D1-AD01-9670EBE5E3DE}</sync-guid><sync-parentguid>{5385B884-11D3-461C-B887-B5B2CF01A321}</sync-parentguid><sync-checksum>256551290</sync-checksum><sync-rootid>0</sync-rootid><sync-itemtype>0</sync-itemtype><sync-timestamp>2003- / Text5: 04-27 18:54:33</sync-timestamp><sync-itemid>10</sync-itemid><sync-prioritymapping>0:0-0/1:700-1000/2:300-699/3:1-299</sync-prioritymapping>
- 11: Text3: <sync-guid>{770A8AEC-AE7F-4D06-BB73-301EA92CD82D}</sync-guid><sync-parentguid>{5385B884-11D3-461C-B887-B5B2CF01A321}</sync-parentguid><sync-checksum>-717107162</sync-checksum><sync-rootid>0</sync-rootid><sync-itemtype>0</sync-itemtype><sync-timestamp>2003 / Text5: -04-27 18:54:33</sync-timestamp><sync-itemid>11</sync-itemid><sync-prioritymapping>0:0-0/1:700-1000/2:300-699/3:1-299</sync-prioritymapping>
- 12: Text3: <sync-guid>{58891831-190D-46C3-8591-7EF81373AD93}</sync-guid><sync-parentguid>{770A8AEC-AE7F-4D06-BB73-301EA92CD82D}</sync-parentguid><sync-checksum>-1214348784</sync-checksum><sync-rootid>0</sync-rootid><sync-itemtype>0</sync-itemtype><sync-timestamp>200 / Text5: 3-04-27 18:54:34</sync-timestamp><sync-itemid>12</sync-itemid><sync-prioritymapping>0:0-0/1:700-1000/2:300-699/3:1-299</sync-prioritymapping>
- 13: Text3: <sync-guid>{0A250DFC-42A0-437B-99A8-A8265109A483}</sync-guid><sync-parentguid>{770A8AEC-AE7F-4D06-BB73-301EA92CD82D}</sync-parentguid><sync-checksum>951254436</sync-checksum><sync-rootid>0</sync-rootid><sync-itemtype>0</sync-itemtype><sync-timestamp>2003- / Text5: 04-27 18:54:34</sync-timestamp><sync-itemid>13</sync-itemid><sync-prioritymapping>0:0-0/1:700-1000/2:300-699/3:1-299</sync-prioritymapping>
- 14: Text3: <sync-guid>{0FFE95B1-039D-4073-9BDB-A844B54516C5}</sync-guid><sync-parentguid>{770A8AEC-AE7F-4D06-BB73-301EA92CD82D}</sync-parentguid><sync-checksum>1596698100</sync-checksum><sync-rootid>0</sync-rootid><sync-itemtype>0</sync-itemtype><sync-timestamp>2003 / Text5: -04-27 18:54:35</sync-timestamp><sync-itemid>14</sync-itemid><sync-prioritymapping>0:0-0/1:700-1000/2:300-699/3:1-299</sync-prioritymapping>
- 15: Text3: <sync-guid>{FF722132-8994-402C-93FA-73F39A49B40D}</sync-guid><sync-parentguid>{770A8AEC-AE7F-4D06-BB73-301EA92CD82D}</sync-parentguid><sync-checksum>1153502304</sync-checksum><sync-rootid>0</sync-rootid><sync-itemtype>0</sync-itemtype><sync-timestamp>2003 / Text5: -04-27 18:54:35</sync-timestamp><sync-itemid>15</sync-itemid><sync-prioritymapping>0:0-0/1:700-1000/2:300-699/3:1-299</sync-prioritymapping>
- 16: Text3: <sync-guid>{C41684D2-5067-402C-8309-4158407C284E}</sync-guid><sync-parentguid>{770A8AEC-AE7F-4D06-BB73-301EA92CD82D}</sync-parentguid><sync-checksum>-448388313</sync-checksum><sync-rootid>0</sync-rootid><sync-itemtype>0</sync-itemtype><sync-timestamp>2003 / Text5: -04-27 18:54:35</sync-timestamp><sync-itemid>16</sync-itemid><sync-prioritymapping>0:0-0/1:700-1000/2:300-699/3:1-299</sync-prioritymapping>
- 17: Text3: <sync-guid>{58CABF62-3F61-4F99-B886-C378758B050C}</sync-guid><sync-parentguid>{770A8AEC-AE7F-4D06-BB73-301EA92CD82D}</sync-parentguid><sync-checksum>-2000398265</sync-checksum><sync-rootid>0</sync-rootid><sync-itemtype>0</sync-itemtype><sync-timestamp>200 / Text5: 3-04-27 18:54:36</sync-timestamp><sync-itemid>17</sync-itemid><sync-prioritymapping>0:0-0/1:700-1000/2:300-699/3:1-299</sync-prioritymapping>
- 18: Text3: <sync-guid>{62DCBF95-503D-4E9E-898B-D6C13F7C3D43}</sync-guid><sync-parentguid>{5385B884-11D3-461C-B887-B5B2CF01A321}</sync-parentguid><sync-checksum>-656634914</sync-checksum><sync-rootid>0</sync-rootid><sync-itemtype>0</sync-itemtype><sync-timestamp>2003 / Text5: -04-27 18:54:36</sync-timestamp><sync-itemid>18</sync-itemid><sync-prioritymapping>0:0-0/1:700-1000/2:300-699/3:1-299</sync-prioritymapping>
- 19: Text3: <sync-guid>{680818D2-0D0A-4194-87C5-D5C420D8DB31}</sync-guid><sync-parentguid>{62DCBF95-503D-4E9E-898B-D6C13F7C3D43}</sync-parentguid><sync-checksum>-2036526201</sync-checksum><sync-rootid>0</sync-rootid><sync-itemtype>0</sync-itemtype><sync-timestamp>200 / Text5: 3-04-27 18:54:36</sync-timestamp><sync-itemid>19</sync-itemid><sync-prioritymapping>0:0-0/1:700-1000/2:300-699/3:1-299</sync-prioritymapping>
- 20: Text3: <sync-guid>{E16A104F-6E3B-4CBB-8660-378C8DEAED01}</sync-guid><sync-parentguid>{62DCBF95-503D-4E9E-898B-D6C13F7C3D43}</sync-parentguid><sync-checksum>-437405551</sync-checksum><sync-rootid>0</sync-rootid><sync-itemtype>0</sync-itemtype><sync-timestamp>2003 / Text5: -04-27 18:54:36</sync-timestamp><sync-itemid>20</sync-itemid><sync-prioritymapping>0:0-0/1:700-1000/2:300-699/3:1-299</sync-prioritymapping>
- 21: Text3: <sync-guid>{D02F746A-244A-4C2E-AB2C-BF197EC09E55}</sync-guid><sync-parentguid>{62DCBF95-503D-4E9E-898B-D6C13F7C3D43}</sync-parentguid><sync-checksum>990181301</sync-checksum><sync-rootid>0</sync-rootid><sync-itemtype>0</sync-itemtype><sync-timestamp>2003- / Text5: 04-27 18:54:37</sync-timestamp><sync-itemid>21</sync-itemid><sync-prioritymapping>0:0-0/1:700-1000/2:300-699/3:1-299</sync-prioritymapping>
- 22: Text3: <sync-guid>{7FB68887-E502-42FC-BD06-73A2FAD70EFC}</sync-guid><sync-parentguid>{62DCBF95-503D-4E9E-898B-D6C13F7C3D43}</sync-parentguid><sync-checksum>-1034811709</sync-checksum><sync-rootid>0</sync-rootid><sync-itemtype>0</sync-itemtype><sync-timestamp>200 / Text5: 3-04-27 18:54:37</sync-timestamp><sync-itemid>22</sync-itemid><sync-prioritymapping>0:0-0/1:700-1000/2:300-699/3:1-299</sync-prioritymapping>
- 23: Text3: <sync-guid>{208B246B-864F-4DCD-BD0C-3D34AB820E2C}</sync-guid><sync-parentguid>{62DCBF95-503D-4E9E-898B-D6C13F7C3D43}</sync-parentguid><sync-checksum>-17365112</sync-checksum><sync-rootid>0</sync-rootid><sync-itemtype>0</sync-itemtype><sync-timestamp>2003- / Text5: 04-27 18:54:37</sync-timestamp><sync-itemid>23</sync-itemid><sync-prioritymapping>0:0-0/1:700-1000/2:300-699/3:1-299</sync-prioritymapping>
- 24: Text3: <sync-guid>{C5B4A003-C2FB-4F48-B0EA-F0038D9C7A82}</sync-guid><sync-parentguid>{62DCBF95-503D-4E9E-898B-D6C13F7C3D43}</sync-parentguid><sync-checksum>-203295981</sync-checksum><sync-rootid>0</sync-rootid><sync-itemtype>0</sync-itemtype><sync-timestamp>2003 / Text5: -04-27 18:54:38</sync-timestamp><sync-itemid>24</sync-itemid><sync-prioritymapping>0:0-0/1:700-1000/2:300-699/3:1-299</sync-prioritymapping>

| ID | WBS | Task | Type | Duration | Start | Finish | Predecessors | Baseline start | Baseline finish | Baseline duration | Total slack | Free slack | Resources | Work | Text4 |
| --- | --- | --- | --- | --- | --- | --- | --- | --- | --- | --- | --- | --- | --- | --- | --- |
| 25 | 2.5 | **Develop Preliminary Project Scope** |  | 19d | 2004-02-13 | 2004-03-10 | 24, 22 | 2004-02-13 | 2004-03-10 | 19d | 0d |  |  | 344h | {4302968B-1D2D-40C8-B052-74A6F6F0C0C3} |
| 26 | 2.5.1 | Define critical success factors |  | 2d | 2004-02-13 | 2004-02-16 |  | 2004-02-13 | 2004-02-16 | 2d | 0d |  | Product management | 16h | {486D2461-3BDC-4EAC-A340-33509145A86E} |
| 27 | 2.5.2 | Define success metrics |  | 1d | 2004-02-17 | 2004-02-17 | 26 | 2004-02-17 | 2004-02-17 | 1d | 0d |  | Product management; Testing | 16h | {E4B86D4D-887D-44AD-AE6B-39EBCA83673F} |
| 28 | 2.5.3 | Define major deliverables (preliminary) |  | 3d | 2004-02-18 | 2004-02-20 | 27 | 2004-02-18 | 2004-02-20 | 3d | 0d |  | Product management [50%]; Program management [50%] | 24h | {79F1923F-F972-4BF8-8E7E-98822791268D} |
| 29 | 2.5.4 | Draft vision/scope |  | 3d | 2004-02-23 | 2004-02-25 | 28 | 2004-02-23 | 2004-02-25 | 3d | 0d |  | Program management; Product management; Development; Testing; Logistics management | 120h | {73E617CD-8AFD-4279-B370-53AD693C89FA} |
| 30 | 2.5.5 | Review vision/scope |  | 2d | 2004-02-26 | 2004-02-27 | 29 | 2004-02-26 | 2004-02-27 | 2d | 0d |  | Program management; Product management; Development; Testing; Logistics management; User education | 96h | {FBBE6990-B2B4-4EAA-992A-F6333E4DB0FE} |
| 31 | 2.5.6 | Update vision/scope |  | 3d | 2004-03-01 | 2004-03-03 | 30 | 2004-03-01 | 2004-03-03 | 3d | 0d |  | Product management | 24h | {F916B409-B182-4E3A-AB73-666FC909A1B2} |
| 32 | 2.5.7 | Buffer |  | 4d | 2004-03-04 | 2004-03-09 | 31 | 2004-03-04 | 2004-03-09 | 4d | 0d |  |  |  | {CB0A9DB7-E26A-408A-B862-2B5AE8BF0388} |
| 33 | 2.5.8 | Perform milestone review |  | 1d | 2004-03-10 | 2004-03-10 | 31, 32 | 2004-03-10 | 2004-03-10 | 1d | 0d |  | Program management; Product management; Development; Testing; Logistics management; User education | 48h | {E585C31F-8BAE-4C19-8A92-DC5CFBF29347} |
| 34 | 2.6 | Vision approved | milestone | 0d | 2004-03-10 | 2004-03-10 | 33, 28, 17, 10 | 2004-03-10 | 2004-03-10 | 0d | 0d |  | Program management; Product management; Development; Testing; Logistics management |  | {C33B9846-82E8-485E-9546-9BC90BF0F856} |
| 35 | 3 | **Planning** |  | 59d | 2004-03-11 | 2004-06-01 | 34 | 2004-03-11 | 2004-06-01 | 59d | 0d |  |  | 3541.2h | {A28F628C-9632-4A42-82F4-B41391CDBFD8} |
| 36 | 3.1 | Update risk assessment |  | 1d | 2004-03-11 | 2004-03-11 | 34 | 2004-03-11 | 2004-03-11 | 1d | 58d |  | Program management | 8h | {7B25786F-742B-4270-AB73-53CF7FB75A22} |
| 37 | 3.2 | Conduct user interviews |  | 10d | 2004-03-11 | 2004-03-24 | 34 | 2004-03-11 | 2004-03-24 | 10d | 0d |  | Product management [50%]; Development [25%]; Testing [25%]; Logistics management [25%]; Program management [50%] | 140h | {2F281930-A080-4A5B-B0D0-B72963E50B61} |
| 38 | 3.3 | **Functional Specification Creation** |  | 31d | 2004-03-12 | 2004-04-23 |  | 2004-03-12 | 2004-04-23 | 31d | 0d |  |  | 448h | {513946AE-9AEB-4E6C-89AF-2021AA9BC65E} |
| 39 | 3.3.1 | Develop functional specification - drop 0 |  | 5d | 2004-03-12 | 2004-03-18 | 37FS-9% | 2004-03-12 | 2004-03-18 | 5d | 0d |  | Program management [80%]; Product management [30%]; Development [40%]; Testing [50%]; Logistics management [40%]; User education [40%] | 112h | {4365A707-B691-47E6-A6BC-20462CE2A518} |
| 40 | 3.3.2 | Develop functional specification - drop 1 |  | 5d | 2004-03-19 | 2004-03-25 | 39 | 2004-03-19 | 2004-03-25 | 5d | 22d | 0d | Program management [80%]; Product management [30%]; Development [40%]; Testing [50%]; Logistics management [40%]; User education [40%] | 112h | {DB5009C2-117C-4C9A-9663-C91FB2C93B78} |
| 41 | 3.3.3 | Develop functional specification - drop 2 |  | 5d | 2004-03-26 | 2004-04-01 | 40 | 2004-03-26 | 2004-04-01 | 5d | 22d | 0d | Program management [80%]; Product management [30%]; Development [40%]; Testing [50%]; Logistics management [40%]; User education [40%] | 112h | {517A9A70-8A39-4BEB-9728-CDF96A1B3310} |
| 42 | 3.3.4 | Develop functional specification - drop n |  | 5d | 2004-04-02 | 2004-04-08 | 41 | 2004-04-02 | 2004-04-08 | 5d | 22d | 11d | Program management [80%]; Product management [30%]; Development [40%]; Testing [50%]; Logistics management [40%]; User education [40%] | 112h | {4F57BF4A-BED4-4A5F-9E34-4DA03DE19AD3} |
| 43 | 3.3.5 | Functional specification baseline | milestone | 0d | 2004-04-23 | 2004-04-23 | 42, 48 | 2004-04-23 | 2004-04-23 | 0d | 11d | 2d | Program management |  | {DB080536-9AB9-42F9-8B28-DD79E7397096} |
| 44 | 3.4 | **Development Plan** |  | 28.25d | 2004-03-17 | 2004-04-26 |  | 2004-03-17 | 2004-04-26 | 28.25d | 0d |  |  | 598.8h | {AF8453D9-4903-422C-A99C-703E798F2BC9} |
| 45 | 3.4.1 | **Create Development Plan** |  | 28d | 2004-03-17 | 2004-04-23 |  | 2004-03-17 | 2004-04-23 | 28d | 0d |  |  | 554.8h | {D3E84AD0-B4EE-43F7-9E73-38B9F94A80AD} |
| 46 | 3.4.1.1 | Conduct conceptual design |  | 10d | 2004-03-17 | 2004-03-30 | 39SS+3d | 2004-03-17 | 2004-03-30 | 10d | 0d |  | Development [80%]; Program management [40%]; Testing [25%]; Product management [20%] | 132h | {DBE829B8-0898-4BE4-8095-E049687B8661} |
| 47 | 3.4.1.2 | Conduct logical design |  | 15d | 2004-03-23 | 2004-04-12 | 46SS+4d | 2004-03-23 | 2004-04-12 | 15d | 0d |  | Development [50%]; Program management [50%]; Testing [25%]; Logistics management [25%]; User education [25%] | 210h | {9ACE218F-D8D6-42D4-A33E-413AA54F96A6} |
| 48 | 3.4.1.3 | Conduct physical design |  | 19d | 2004-03-30 | 2004-04-23 | 47SS+5d | 2004-03-30 | 2004-04-23 | 19d | 0d |  | Development [80%]; Testing [50%]; Program management [10%] | 212.8h | {ABEE3D89-A7D0-4F01-97B0-32541BC46781} |
| 49 | 3.4.2 | Develop development schedule |  | 5d | 2004-04-19 | 2004-04-26 | 48SS+7.5% | 2004-04-19 | 2004-04-26 | 5d | 15.75d |  | Development; Testing [10%] | 44h | {0F70C498-F26A-40EB-ACB5-469635D89116} |

Notes:
- 25: Text3: <sync-guid>{4302968B-1D2D-40C8-B052-74A6F6F0C0C3}</sync-guid><sync-parentguid>{5385B884-11D3-461C-B887-B5B2CF01A321}</sync-parentguid><sync-checksum>1227910179</sync-checksum><sync-rootid>0</sync-rootid><sync-itemtype>0</sync-itemtype><sync-timestamp>2003 / Text5: -04-27 18:54:38</sync-timestamp><sync-itemid>25</sync-itemid><sync-prioritymapping>0:0-0/1:700-1000/2:300-699/3:1-299</sync-prioritymapping>
- 26: Text3: <sync-guid>{486D2461-3BDC-4EAC-A340-33509145A86E}</sync-guid><sync-parentguid>{4302968B-1D2D-40C8-B052-74A6F6F0C0C3}</sync-parentguid><sync-checksum>55697930</sync-checksum><sync-rootid>0</sync-rootid><sync-itemtype>0</sync-itemtype><sync-timestamp>2003-0 / Text5: 4-27 18:54:38</sync-timestamp><sync-itemid>26</sync-itemid><sync-prioritymapping>0:0-0/1:700-1000/2:300-699/3:1-299</sync-prioritymapping>
- 27: Text3: <sync-guid>{E4B86D4D-887D-44AD-AE6B-39EBCA83673F}</sync-guid><sync-parentguid>{4302968B-1D2D-40C8-B052-74A6F6F0C0C3}</sync-parentguid><sync-checksum>-170545632</sync-checksum><sync-rootid>0</sync-rootid><sync-itemtype>0</sync-itemtype><sync-timestamp>2003 / Text5: -04-27 18:54:39</sync-timestamp><sync-itemid>27</sync-itemid><sync-prioritymapping>0:0-0/1:700-1000/2:300-699/3:1-299</sync-prioritymapping>
- 28: Text3: <sync-guid>{79F1923F-F972-4BF8-8E7E-98822791268D}</sync-guid><sync-parentguid>{4302968B-1D2D-40C8-B052-74A6F6F0C0C3}</sync-parentguid><sync-checksum>321026239</sync-checksum><sync-rootid>0</sync-rootid><sync-itemtype>0</sync-itemtype><sync-timestamp>2003- / Text5: 04-27 18:54:39</sync-timestamp><sync-itemid>28</sync-itemid><sync-prioritymapping>0:0-0/1:700-1000/2:300-699/3:1-299</sync-prioritymapping>
- 29: Text3: <sync-guid>{73E617CD-8AFD-4279-B370-53AD693C89FA}</sync-guid><sync-parentguid>{4302968B-1D2D-40C8-B052-74A6F6F0C0C3}</sync-parentguid><sync-checksum>1440352878</sync-checksum><sync-rootid>0</sync-rootid><sync-itemtype>0</sync-itemtype><sync-timestamp>2003 / Text5: -04-27 18:54:39</sync-timestamp><sync-itemid>29</sync-itemid><sync-prioritymapping>0:0-0/1:700-1000/2:300-699/3:1-299</sync-prioritymapping>
- 30: Text3: <sync-guid>{FBBE6990-B2B4-4EAA-992A-F6333E4DB0FE}</sync-guid><sync-parentguid>{4302968B-1D2D-40C8-B052-74A6F6F0C0C3}</sync-parentguid><sync-checksum>1321559933</sync-checksum><sync-rootid>0</sync-rootid><sync-itemtype>0</sync-itemtype><sync-timestamp>2003 / Text5: -04-27 18:54:40</sync-timestamp><sync-itemid>30</sync-itemid><sync-prioritymapping>0:0-0/1:700-1000/2:300-699/3:1-299</sync-prioritymapping>
- 31: Text3: <sync-guid>{F916B409-B182-4E3A-AB73-666FC909A1B2}</sync-guid><sync-parentguid>{4302968B-1D2D-40C8-B052-74A6F6F0C0C3}</sync-parentguid><sync-checksum>-1973346930</sync-checksum><sync-rootid>0</sync-rootid><sync-itemtype>0</sync-itemtype><sync-timestamp>200 / Text5: 3-04-27 18:54:40</sync-timestamp><sync-itemid>31</sync-itemid><sync-prioritymapping>0:0-0/1:700-1000/2:300-699/3:1-299</sync-prioritymapping>
- 32: Text3: <sync-guid>{CB0A9DB7-E26A-408A-B862-2B5AE8BF0388}</sync-guid><sync-parentguid>{4302968B-1D2D-40C8-B052-74A6F6F0C0C3}</sync-parentguid><sync-checksum>183097913</sync-checksum><sync-rootid>0</sync-rootid><sync-itemtype>0</sync-itemtype><sync-timestamp>2003- / Text5: 04-27 18:54:40</sync-timestamp><sync-itemid>32</sync-itemid><sync-prioritymapping>0:0-0/1:700-1000/2:300-699/3:1-299</sync-prioritymapping>
- 33: Text3: <sync-guid>{E585C31F-8BAE-4C19-8A92-DC5CFBF29347}</sync-guid><sync-parentguid>{4302968B-1D2D-40C8-B052-74A6F6F0C0C3}</sync-parentguid><sync-checksum>654556216</sync-checksum><sync-rootid>0</sync-rootid><sync-itemtype>0</sync-itemtype><sync-timestamp>2003- / Text5: 04-27 18:54:41</sync-timestamp><sync-itemid>33</sync-itemid><sync-prioritymapping>0:0-0/1:700-1000/2:300-699/3:1-299</sync-prioritymapping>
- 34: Text3: <sync-guid>{C33B9846-82E8-485E-9546-9BC90BF0F856}</sync-guid><sync-parentguid>{5385B884-11D3-461C-B887-B5B2CF01A321}</sync-parentguid><sync-checksum>1116257240</sync-checksum><sync-rootid>0</sync-rootid><sync-itemtype>0</sync-itemtype><sync-timestamp>2003 / Text5: -04-27 18:54:41</sync-timestamp><sync-itemid>34</sync-itemid><sync-prioritymapping>0:0-0/1:700-1000/2:300-699/3:1-299</sync-prioritymapping>
- 35: Text3: <sync-guid>{A28F628C-9632-4A42-82F4-B41391CDBFD8}</sync-guid><sync-parentguid>{7132D1D4-D456-4D63-BFC8-4726AD2508E4}</sync-parentguid><sync-checksum>-412647556</sync-checksum><sync-rootid>0</sync-rootid><sync-itemtype>0</sync-itemtype><sync-timestamp>2003 / Text5: -04-27 18:54:41</sync-timestamp><sync-itemid>35</sync-itemid><sync-prioritymapping>0:0-0/1:700-1000/2:300-699/3:1-299</sync-prioritymapping>
- 36: This task should continue to occur throughout the Planning phase. One way to represent this is to do a paste link from the start date of task 37 to the start date of this task, and then do a paste link from the finish date of 78 to the finish date of this task. See the template Help file for more details. / Text3: <sync-guid>{7B25786F-742B-4270-AB73-53CF7FB75A22}</sync-guid><sync-parentguid>{A28F628C-9632-4A42-82F4-B41391CDBFD8}</sync-parentguid><sync-checksum>1676961137</sync-checksum><sync-rootid>0</sync-rootid><sync-itemtype>0</sync-itemtype><sync-timestamp>2003 / Text5: -04-27 18:54:42</sync-timestamp><sync-itemid>36</sync-itemid><sync-prioritymapping>0:0-0/1:700-1000/2:300-699/3:1-299</sync-prioritymapping>
- 37: Text3: <sync-guid>{2F281930-A080-4A5B-B0D0-B72963E50B61}</sync-guid><sync-parentguid>{A28F628C-9632-4A42-82F4-B41391CDBFD8}</sync-parentguid><sync-checksum>188896050</sync-checksum><sync-rootid>0</sync-rootid><sync-itemtype>0</sync-itemtype><sync-timestamp>2003- / Text5: 04-27 18:54:42</sync-timestamp><sync-itemid>37</sync-itemid><sync-prioritymapping>0:0-0/1:700-1000/2:300-699/3:1-299</sync-prioritymapping>
- 38: Text3: <sync-guid>{513946AE-9AEB-4E6C-89AF-2021AA9BC65E}</sync-guid><sync-parentguid>{A28F628C-9632-4A42-82F4-B41391CDBFD8}</sync-parentguid><sync-checksum>1479200034</sync-checksum><sync-rootid>0</sync-rootid><sync-itemtype>0</sync-itemtype><sync-timestamp>2003 / Text5: -04-27 18:54:42</sync-timestamp><sync-itemid>38</sync-itemid><sync-prioritymapping>0:0-0/1:700-1000/2:300-699/3:1-299</sync-prioritymapping>
- 39: Text3: <sync-guid>{4365A707-B691-47E6-A6BC-20462CE2A518}</sync-guid><sync-parentguid>{513946AE-9AEB-4E6C-89AF-2021AA9BC65E}</sync-parentguid><sync-checksum>736129691</sync-checksum><sync-rootid>0</sync-rootid><sync-itemtype>0</sync-itemtype><sync-timestamp>2003- / Text5: 04-27 18:54:43</sync-timestamp><sync-itemid>39</sync-itemid><sync-prioritymapping>0:0-0/1:700-1000/2:300-699/3:1-299</sync-prioritymapping>
- 40: Text3: <sync-guid>{DB5009C2-117C-4C9A-9663-C91FB2C93B78}</sync-guid><sync-parentguid>{513946AE-9AEB-4E6C-89AF-2021AA9BC65E}</sync-parentguid><sync-checksum>2127919855</sync-checksum><sync-rootid>0</sync-rootid><sync-itemtype>0</sync-itemtype><sync-timestamp>2003 / Text5: -04-27 18:54:43</sync-timestamp><sync-itemid>40</sync-itemid><sync-prioritymapping>0:0-0/1:700-1000/2:300-699/3:1-299</sync-prioritymapping>
- 41: Text3: <sync-guid>{517A9A70-8A39-4BEB-9728-CDF96A1B3310}</sync-guid><sync-parentguid>{513946AE-9AEB-4E6C-89AF-2021AA9BC65E}</sync-parentguid><sync-checksum>-330285947</sync-checksum><sync-rootid>0</sync-rootid><sync-itemtype>0</sync-itemtype><sync-timestamp>2003 / Text5: -04-27 18:54:44</sync-timestamp><sync-itemid>41</sync-itemid><sync-prioritymapping>0:0-0/1:700-1000/2:300-699/3:1-299</sync-prioritymapping>
- 42: Text3: <sync-guid>{4F57BF4A-BED4-4A5F-9E34-4DA03DE19AD3}</sync-guid><sync-parentguid>{513946AE-9AEB-4E6C-89AF-2021AA9BC65E}</sync-parentguid><sync-checksum>-365694610</sync-checksum><sync-rootid>0</sync-rootid><sync-itemtype>0</sync-itemtype><sync-timestamp>2003 / Text5: -04-27 18:54:44</sync-timestamp><sync-itemid>42</sync-itemid><sync-prioritymapping>0:0-0/1:700-1000/2:300-699/3:1-299</sync-prioritymapping>
- 43: Text3: <sync-guid>{DB080536-9AB9-42F9-8B28-DD79E7397096}</sync-guid><sync-parentguid>{513946AE-9AEB-4E6C-89AF-2021AA9BC65E}</sync-parentguid><sync-checksum>1698697370</sync-checksum><sync-rootid>0</sync-rootid><sync-itemtype>0</sync-itemtype><sync-timestamp>2003 / Text5: -04-27 18:54:45</sync-timestamp><sync-itemid>43</sync-itemid><sync-prioritymapping>0:0-0/1:700-1000/2:300-699/3:1-299</sync-prioritymapping>
- 44: Text3: <sync-guid>{AF8453D9-4903-422C-A99C-703E798F2BC9}</sync-guid><sync-parentguid>{A28F628C-9632-4A42-82F4-B41391CDBFD8}</sync-parentguid><sync-checksum>-1694996484</sync-checksum><sync-rootid>0</sync-rootid><sync-itemtype>0</sync-itemtype><sync-timestamp>200 / Text5: 3-04-27 18:54:45</sync-timestamp><sync-itemid>44</sync-itemid><sync-prioritymapping>0:0-0/1:700-1000/2:300-699/3:1-299</sync-prioritymapping>
- 45: Text3: <sync-guid>{D3E84AD0-B4EE-43F7-9E73-38B9F94A80AD}</sync-guid><sync-parentguid>{AF8453D9-4903-422C-A99C-703E798F2BC9}</sync-parentguid><sync-checksum>-1974379232</sync-checksum><sync-rootid>0</sync-rootid><sync-itemtype>0</sync-itemtype><sync-timestamp>200 / Text5: 3-04-27 18:54:45</sync-timestamp><sync-itemid>45</sync-itemid><sync-prioritymapping>0:0-0/1:700-1000/2:300-699/3:1-299</sync-prioritymapping>
- 46: Text3: <sync-guid>{DBE829B8-0898-4BE4-8095-E049687B8661}</sync-guid><sync-parentguid>{D3E84AD0-B4EE-43F7-9E73-38B9F94A80AD}</sync-parentguid><sync-checksum>609516777</sync-checksum><sync-rootid>0</sync-rootid><sync-itemtype>0</sync-itemtype><sync-timestamp>2003- / Text5: 04-27 18:54:45</sync-timestamp><sync-itemid>46</sync-itemid><sync-prioritymapping>0:0-0/1:700-1000/2:300-699/3:1-299</sync-prioritymapping>
- 47: Text3: <sync-guid>{9ACE218F-D8D6-42D4-A33E-413AA54F96A6}</sync-guid><sync-parentguid>{D3E84AD0-B4EE-43F7-9E73-38B9F94A80AD}</sync-parentguid><sync-checksum>-83630447</sync-checksum><sync-rootid>0</sync-rootid><sync-itemtype>0</sync-itemtype><sync-timestamp>2003- / Text5: 04-27 18:54:46</sync-timestamp><sync-itemid>47</sync-itemid><sync-prioritymapping>0:0-0/1:700-1000/2:300-699/3:1-299</sync-prioritymapping>
- 48: Text3: <sync-guid>{ABEE3D89-A7D0-4F01-97B0-32541BC46781}</sync-guid><sync-parentguid>{D3E84AD0-B4EE-43F7-9E73-38B9F94A80AD}</sync-parentguid><sync-checksum>1747072493</sync-checksum><sync-rootid>0</sync-rootid><sync-itemtype>0</sync-itemtype><sync-timestamp>2003 / Text5: -04-27 18:54:46</sync-timestamp><sync-itemid>48</sync-itemid><sync-prioritymapping>0:0-0/1:700-1000/2:300-699/3:1-299</sync-prioritymapping>
- 49: Text3: <sync-guid>{0F70C498-F26A-40EB-ACB5-469635D89116}</sync-guid><sync-parentguid>{AF8453D9-4903-422C-A99C-703E798F2BC9}</sync-parentguid><sync-checksum>-1566630283</sync-checksum><sync-rootid>0</sync-rootid><sync-itemtype>0</sync-itemtype><sync-timestamp>200 / Text5: 3-04-27 18:54:47</sync-timestamp><sync-itemid>49</sync-itemid><sync-prioritymapping>0:0-0/1:700-1000/2:300-699/3:1-299</sync-prioritymapping>

| ID | WBS | Task | Type | Duration | Start | Finish | Predecessors | Baseline start | Baseline finish | Baseline duration | Total slack | Free slack | Resources | Work | Text4 |
| --- | --- | --- | --- | --- | --- | --- | --- | --- | --- | --- | --- | --- | --- | --- | --- |
| 50 | 3.5 | **Test Plan** |  | 35d | 2004-03-17 | 2004-05-04 |  | 2004-03-17 | 2004-05-04 | 35d | 9d |  | Testing | 624h | {236A5FEE-2D72-4549-8AC8-1DFDD4A20036} |
| 51 | 3.5.1 | Develop test plan |  | 30d | 2004-03-17 | 2004-04-27 | 39SS+3d | 2004-03-17 | 2004-04-27 | 30d | 9d | 0d | Testing; Program management [25%] | 300h | {CD330D2F-CE0C-4477-BD5D-9B7959B45331} |
| 52 | 3.5.2 | Develop test schedule |  | 5d | 2004-04-28 | 2004-05-04 | 51, 43 | 2004-04-28 | 2004-05-04 | 5d | 9d |  | Testing; Program management [10%] | 44h | {9E818D9D-FE7E-4837-8F76-CF254C03F774} |
| 53 | 3.6 | **User Education Plan** |  | 36d | 2004-03-17 | 2004-05-05 |  | 2004-03-17 | 2004-05-05 | 36d | 8d |  | User education | 691.2h | {101AFEE2-3CD6-48F4-A4D0-21CDB9F29A49} |
| 54 | 3.6.1 | Develop user education plan |  | 30d | 2004-03-17 | 2004-04-27 | 39SS+3d | 2004-03-17 | 2004-04-27 | 30d | 8d | 0d | User education; Testing [20%]; Product management [10%]; Customer [10%] | 336h | {2DB42D90-3BC8-4596-AA8B-C502D26CA13F} |
| 55 | 3.6.2 | Develop user education schedule |  | 6d | 2004-04-28 | 2004-05-05 | 54 | 2004-04-28 | 2004-05-05 | 6d | 8d |  | User education; Program management [10%]; Product management [20%]; Customer [10%] | 67.2h | {EE982F66-72BC-4A71-954C-B6673E7167A8} |
| 56 | 3.7 | **Logistics Plan** |  | 48d | 2004-03-11 | 2004-05-17 |  | 2004-03-11 | 2004-05-17 | 48d | 0d |  | Logistics management | 705.6h | {D64EB382-907E-4138-A812-34699846ACBF} |
| 57 | 3.7.1 | **Develop Logistics Plan** |  | 43d | 2004-03-11 | 2004-05-10 |  | 2004-03-11 | 2004-05-10 | 43d | 0d |  |  | 321.6h | {255D293E-8CEF-4B22-8C20-EFFCF849CB7F} |
| 58 | 3.7.1.1 | Perform infrastructure analysis |  | 15d | 2004-03-11 | 2004-03-31 |  | 2004-03-11 | 2004-03-31 | 15d | 1d |  |  |  | {4803AD62-51EA-4B66-873C-E0AEB5672A2F} |
| 59 | 3.7.1.2 | Develop security plan |  | 2d | 2004-03-19 | 2004-03-22 | 39 | 2004-03-19 | 2004-03-22 | 2d | 8d |  | Logistics management; Customer [10%]; Product management [10%] | 19.2h | {E5B50485-3579-458C-BF85-510878949C15} |
| 60 | 3.7.1.3 | Develop deployment plan |  | 27d | 2004-04-02 | 2004-05-10 | 39FS-3d, 59, 48SS+3d, 58 | 2004-04-02 | 2004-05-10 | 27d | 0d |  | Logistics management; Testing [20%]; User education [10%]; Customer [10%] | 302.4h | {FC1677FC-79C6-4C5E-B5A1-8B433A43EE14} |
| 61 | 3.7.1.4 | Order components |  | 15d | 2004-04-16 | 2004-05-06 | 60SS+10d | 2004-04-16 | 2004-05-06 | 15d | 0d |  |  |  | {EC2031AE-A209-4F68-AABC-256F8EA1A334} |
| 62 | 3.7.1.5 | Logistics plan complete | milestone | 0d | 2004-05-06 | 2004-05-06 | 59, 61 | 2004-05-06 | 2004-05-06 | 0d | 0d |  |  |  | {A7E9CD26-8372-4FE2-825B-F2E90CBCC6B7} |
| 63 | 3.7.2 | Create logistics schedule |  | 7d | 2004-05-07 | 2004-05-17 | 62 | 2004-05-07 | 2004-05-17 | 7d | 0d |  |  |  | {F4D609EB-4496-47D2-94C7-A7F0557084BA} |
| 64 | 3.8 | **Product Management Plan** |  | 18d | 2004-03-11 | 2004-04-05 |  | 2004-03-11 | 2004-04-05 | 18d | 30d |  |  | 48h | {4E9B12A7-B966-4360-9D53-0FE08C02097E} |
| 65 | 3.8.1 | Develop product management plan |  | 14d | 2004-03-17 | 2004-04-05 | 39SS+3d | 2004-03-17 | 2004-04-05 | 14d | 30d |  |  |  | {31ECBE07-E490-4127-9BE2-50EAE9F33F3F} |
| 66 | 3.8.2 | Develop product management schedule |  | 5d | 2004-03-11 | 2004-03-17 |  | 2004-03-11 | 2004-03-17 | 5d | 43d |  | Product management; Program management [20%] | 48h | {B54BE480-0E51-4A13-BE72-C261A3B8D3F5} |
| 67 | 3.9 | **Program Management Plan** |  | 41d | 2004-03-17 | 2004-05-12 | 39SS+3d | 2004-03-17 | 2004-05-12 | 41d | 3d |  |  | 164h | {D79F9EEC-3B54-4D4F-AC48-584A435372EE} |
| 68 | 3.9.1 | Create program management plan |  | 21d | 2004-03-17 | 2004-04-14 | 39SS+3d | 2004-03-17 | 2004-04-14 | 21d | 3d | 0d | Program management [50%] | 84h | {D89C24E2-0E11-4E3B-B599-CBF0CBF55ECA} |
| 69 | 3.9.2 | Create program management schedule |  | 20d | 2004-04-15 | 2004-05-12 | 68 | 2004-04-15 | 2004-05-12 | 20d | 3d |  | Program management [50%] | 80h | {62F2A76D-A459-4856-AD08-E6F30490AB71} |
| 70 | 3.10 | Project plan baseline established | milestone | 0d | 2004-05-17 | 2004-05-17 | 44, 50, 53, 56, 64, 67, 65 | 2004-05-17 | 2004-05-17 | 0d | 0d |  | Program management; Product management; Development; Testing; Logistics management |  | {7552694F-D63E-42A1-AD43-B9834DD3BFEE} |
| 71 | 3.11 | **Consolidate Project Plans** |  | 11d | 2004-05-18 | 2004-06-01 | 70 | 2004-05-18 | 2004-06-01 | 11d | 0d |  |  | 113.6h | {3FF4E49B-D961-4843-905E-8F2221DA6069} |
| 72 | 3.11.1 | Review aggregate plan |  | 4d | 2004-05-18 | 2004-05-21 |  | 2004-05-18 | 2004-05-21 | 4d | 0d |  | Program management [30%]; Product management [30%]; Development [30%]; Testing [30%]; Logistics management [30%]; User education [30%] | 57.6h | {3ADC0A5E-6A5F-437B-8715-B9E61EE74414} |
| 73 | 3.11.2 | Create aggregate schedule |  | 2d | 2004-05-24 | 2004-05-25 | 72, 63, 69, 49, 52, 55, 66 | 2004-05-24 | 2004-05-25 | 2d | 0d |  |  |  | {A10EDE6E-6841-48D8-9763-3303BD9B2F0D} |
| 74 | 3.11.3 | Buffer |  | 4d | 2004-05-26 | 2004-05-31 | 73 | 2004-05-26 | 2004-05-31 | 4d | 0d |  |  |  | {2CEF89D5-3881-4511-9020-BD308921E061} |
| 75 | 3.11.4 | Determine ship date | milestone | 0d | 2004-05-31 | 2004-05-31 | 74 | 2004-05-31 | 2004-05-31 | 0d | 0d |  | Program management; Product management; Development; Testing; Logistics management; User education |  | {9F123A27-5D8E-4DA6-9592-B4CD01192658} |
| 76 | 3.11.5 | Vision/scope frozen | milestone | 0d | 2004-05-31 | 2004-05-31 | 75 | 2004-05-31 | 2004-05-31 | 0d | 0d |  |  |  | {86DF9110-9170-4B24-BEAF-E6B7AC231C7B} |
| 77 | 3.11.6 | Perform milestone review |  | 1d | 2004-06-01 | 2004-06-01 | 76 | 2004-06-01 | 2004-06-01 | 1d | 0d |  | Program management; Product management; Development; Testing; Logistics management; User education; Customer | 56h | {BB67FDD3-1DD7-4A31-87E8-E194ED959BC8} |
| 78 | 3.12 | Project plan approved | milestone | 0d | 2004-06-01 | 2004-06-01 | 71, 77, 36 | 2004-06-01 | 2004-06-01 | 0d | 0d |  | Program management; Product management; Development; Testing; Logistics management |  | {905BD7EE-6976-4C31-999D-F590DB784CED} |

Notes:
- 50: Text3: <sync-guid>{236A5FEE-2D72-4549-8AC8-1DFDD4A20036}</sync-guid><sync-parentguid>{A28F628C-9632-4A42-82F4-B41391CDBFD8}</sync-parentguid><sync-checksum>-2016558263</sync-checksum><sync-rootid>0</sync-rootid><sync-itemtype>0</sync-itemtype><sync-timestamp>200 / Text5: 3-04-27 18:54:47</sync-timestamp><sync-itemid>50</sync-itemid><sync-prioritymapping>0:0-0/1:700-1000/2:300-699/3:1-299</sync-prioritymapping>
- 51: Text3: <sync-guid>{CD330D2F-CE0C-4477-BD5D-9B7959B45331}</sync-guid><sync-parentguid>{236A5FEE-2D72-4549-8AC8-1DFDD4A20036}</sync-parentguid><sync-checksum>-678040531</sync-checksum><sync-rootid>0</sync-rootid><sync-itemtype>0</sync-itemtype><sync-timestamp>2003 / Text5: -04-27 18:54:47</sync-timestamp><sync-itemid>51</sync-itemid><sync-prioritymapping>0:0-0/1:700-1000/2:300-699/3:1-299</sync-prioritymapping>
- 52: Text3: <sync-guid>{9E818D9D-FE7E-4837-8F76-CF254C03F774}</sync-guid><sync-parentguid>{236A5FEE-2D72-4549-8AC8-1DFDD4A20036}</sync-parentguid><sync-checksum>-1595403441</sync-checksum><sync-rootid>0</sync-rootid><sync-itemtype>0</sync-itemtype><sync-timestamp>200 / Text5: 3-04-27 18:54:48</sync-timestamp><sync-itemid>52</sync-itemid><sync-prioritymapping>0:0-0/1:700-1000/2:300-699/3:1-299</sync-prioritymapping>
- 53: Text3: <sync-guid>{101AFEE2-3CD6-48F4-A4D0-21CDB9F29A49}</sync-guid><sync-parentguid>{A28F628C-9632-4A42-82F4-B41391CDBFD8}</sync-parentguid><sync-checksum>-210149858</sync-checksum><sync-rootid>0</sync-rootid><sync-itemtype>0</sync-itemtype><sync-timestamp>2003 / Text5: -04-27 18:54:48</sync-timestamp><sync-itemid>53</sync-itemid><sync-prioritymapping>0:0-0/1:700-1000/2:300-699/3:1-299</sync-prioritymapping>
- 54: Text3: <sync-guid>{2DB42D90-3BC8-4596-AA8B-C502D26CA13F}</sync-guid><sync-parentguid>{101AFEE2-3CD6-48F4-A4D0-21CDB9F29A49}</sync-parentguid><sync-checksum>-1102430689</sync-checksum><sync-rootid>0</sync-rootid><sync-itemtype>0</sync-itemtype><sync-timestamp>200 / Text5: 3-04-27 18:54:48</sync-timestamp><sync-itemid>54</sync-itemid><sync-prioritymapping>0:0-0/1:700-1000/2:300-699/3:1-299</sync-prioritymapping>
- 55: Text3: <sync-guid>{EE982F66-72BC-4A71-954C-B6673E7167A8}</sync-guid><sync-parentguid>{101AFEE2-3CD6-48F4-A4D0-21CDB9F29A49}</sync-parentguid><sync-checksum>-1297882938</sync-checksum><sync-rootid>0</sync-rootid><sync-itemtype>0</sync-itemtype><sync-timestamp>200 / Text5: 3-04-27 18:54:49</sync-timestamp><sync-itemid>55</sync-itemid><sync-prioritymapping>0:0-0/1:700-1000/2:300-699/3:1-299</sync-prioritymapping>
- 56: Text3: <sync-guid>{D64EB382-907E-4138-A812-34699846ACBF}</sync-guid><sync-parentguid>{A28F628C-9632-4A42-82F4-B41391CDBFD8}</sync-parentguid><sync-checksum>1059192214</sync-checksum><sync-rootid>0</sync-rootid><sync-itemtype>0</sync-itemtype><sync-timestamp>2003 / Text5: -04-27 18:54:49</sync-timestamp><sync-itemid>56</sync-itemid><sync-prioritymapping>0:0-0/1:700-1000/2:300-699/3:1-299</sync-prioritymapping>
- 57: Text3: <sync-guid>{255D293E-8CEF-4B22-8C20-EFFCF849CB7F}</sync-guid><sync-parentguid>{D64EB382-907E-4138-A812-34699846ACBF}</sync-parentguid><sync-checksum>-780085194</sync-checksum><sync-rootid>0</sync-rootid><sync-itemtype>0</sync-itemtype><sync-timestamp>2003 / Text5: -04-27 18:54:49</sync-timestamp><sync-itemid>57</sync-itemid><sync-prioritymapping>0:0-0/1:700-1000/2:300-699/3:1-299</sync-prioritymapping>
- 58: Text3: <sync-guid>{4803AD62-51EA-4B66-873C-E0AEB5672A2F}</sync-guid><sync-parentguid>{255D293E-8CEF-4B22-8C20-EFFCF849CB7F}</sync-parentguid><sync-checksum>-1984360834</sync-checksum><sync-rootid>0</sync-rootid><sync-itemtype>0</sync-itemtype><sync-timestamp>200 / Text5: 3-04-27 18:54:50</sync-timestamp><sync-itemid>58</sync-itemid><sync-prioritymapping>0:0-0/1:700-1000/2:300-699/3:1-299</sync-prioritymapping>
- 59: Text3: <sync-guid>{E5B50485-3579-458C-BF85-510878949C15}</sync-guid><sync-parentguid>{255D293E-8CEF-4B22-8C20-EFFCF849CB7F}</sync-parentguid><sync-checksum>-645873694</sync-checksum><sync-rootid>0</sync-rootid><sync-itemtype>0</sync-itemtype><sync-timestamp>2003 / Text5: -04-27 18:54:50</sync-timestamp><sync-itemid>59</sync-itemid><sync-prioritymapping>0:0-0/1:700-1000/2:300-699/3:1-299</sync-prioritymapping>
- 60: Text3: <sync-guid>{FC1677FC-79C6-4C5E-B5A1-8B433A43EE14}</sync-guid><sync-parentguid>{255D293E-8CEF-4B22-8C20-EFFCF849CB7F}</sync-parentguid><sync-checksum>-133384551</sync-checksum><sync-rootid>0</sync-rootid><sync-itemtype>0</sync-itemtype><sync-timestamp>2003 / Text5: -04-27 18:54:51</sync-timestamp><sync-itemid>60</sync-itemid><sync-prioritymapping>0:0-0/1:700-1000/2:300-699/3:1-299</sync-prioritymapping>
- 61: Text3: <sync-guid>{EC2031AE-A209-4F68-AABC-256F8EA1A334}</sync-guid><sync-parentguid>{255D293E-8CEF-4B22-8C20-EFFCF849CB7F}</sync-parentguid><sync-checksum>-21048035</sync-checksum><sync-rootid>0</sync-rootid><sync-itemtype>0</sync-itemtype><sync-timestamp>2003- / Text5: 04-27 18:54:51</sync-timestamp><sync-itemid>61</sync-itemid><sync-prioritymapping>0:0-0/1:700-1000/2:300-699/3:1-299</sync-prioritymapping>
- 62: Text3: <sync-guid>{A7E9CD26-8372-4FE2-825B-F2E90CBCC6B7}</sync-guid><sync-parentguid>{255D293E-8CEF-4B22-8C20-EFFCF849CB7F}</sync-parentguid><sync-checksum>-837022747</sync-checksum><sync-rootid>0</sync-rootid><sync-itemtype>0</sync-itemtype><sync-timestamp>2003 / Text5: -04-27 18:54:51</sync-timestamp><sync-itemid>62</sync-itemid><sync-prioritymapping>0:0-0/1:700-1000/2:300-699/3:1-299</sync-prioritymapping>
- 63: Text3: <sync-guid>{F4D609EB-4496-47D2-94C7-A7F0557084BA}</sync-guid><sync-parentguid>{D64EB382-907E-4138-A812-34699846ACBF}</sync-parentguid><sync-checksum>-1087742162</sync-checksum><sync-rootid>0</sync-rootid><sync-itemtype>0</sync-itemtype><sync-timestamp>200 / Text5: 3-04-27 18:54:52</sync-timestamp><sync-itemid>63</sync-itemid><sync-prioritymapping>0:0-0/1:700-1000/2:300-699/3:1-299</sync-prioritymapping>
- 64: Text3: <sync-guid>{4E9B12A7-B966-4360-9D53-0FE08C02097E}</sync-guid><sync-parentguid>{A28F628C-9632-4A42-82F4-B41391CDBFD8}</sync-parentguid><sync-checksum>-1294592659</sync-checksum><sync-rootid>0</sync-rootid><sync-itemtype>0</sync-itemtype><sync-timestamp>200 / Text5: 3-04-27 18:54:52</sync-timestamp><sync-itemid>64</sync-itemid><sync-prioritymapping>0:0-0/1:700-1000/2:300-699/3:1-299</sync-prioritymapping>
- 65: Text3: <sync-guid>{31ECBE07-E490-4127-9BE2-50EAE9F33F3F}</sync-guid><sync-parentguid>{4E9B12A7-B966-4360-9D53-0FE08C02097E}</sync-parentguid><sync-checksum>-1151515187</sync-checksum><sync-rootid>0</sync-rootid><sync-itemtype>0</sync-itemtype><sync-timestamp>200 / Text5: 3-04-27 18:54:52</sync-timestamp><sync-itemid>65</sync-itemid><sync-prioritymapping>0:0-0/1:700-1000/2:300-699/3:1-299</sync-prioritymapping>
- 66: Text3: <sync-guid>{B54BE480-0E51-4A13-BE72-C261A3B8D3F5}</sync-guid><sync-parentguid>{4E9B12A7-B966-4360-9D53-0FE08C02097E}</sync-parentguid><sync-checksum>-1190469003</sync-checksum><sync-rootid>0</sync-rootid><sync-itemtype>0</sync-itemtype><sync-timestamp>200 / Text5: 3-04-27 18:54:52</sync-timestamp><sync-itemid>66</sync-itemid><sync-prioritymapping>0:0-0/1:700-1000/2:300-699/3:1-299</sync-prioritymapping>
- 67: Text3: <sync-guid>{D79F9EEC-3B54-4D4F-AC48-584A435372EE}</sync-guid><sync-parentguid>{A28F628C-9632-4A42-82F4-B41391CDBFD8}</sync-parentguid><sync-checksum>-948026767</sync-checksum><sync-rootid>0</sync-rootid><sync-itemtype>0</sync-itemtype><sync-timestamp>2003 / Text5: -04-27 18:54:53</sync-timestamp><sync-itemid>67</sync-itemid><sync-prioritymapping>0:0-0/1:700-1000/2:300-699/3:1-299</sync-prioritymapping>
- 68: Text3: <sync-guid>{D89C24E2-0E11-4E3B-B599-CBF0CBF55ECA}</sync-guid><sync-parentguid>{D79F9EEC-3B54-4D4F-AC48-584A435372EE}</sync-parentguid><sync-checksum>1146743682</sync-checksum><sync-rootid>0</sync-rootid><sync-itemtype>0</sync-itemtype><sync-timestamp>2003 / Text5: -04-27 18:54:53</sync-timestamp><sync-itemid>68</sync-itemid><sync-prioritymapping>0:0-0/1:700-1000/2:300-699/3:1-299</sync-prioritymapping>
- 69: Text3: <sync-guid>{62F2A76D-A459-4856-AD08-E6F30490AB71}</sync-guid><sync-parentguid>{D79F9EEC-3B54-4D4F-AC48-584A435372EE}</sync-parentguid><sync-checksum>2080676279</sync-checksum><sync-rootid>0</sync-rootid><sync-itemtype>0</sync-itemtype><sync-timestamp>2003 / Text5: -04-27 18:54:53</sync-timestamp><sync-itemid>69</sync-itemid><sync-prioritymapping>0:0-0/1:700-1000/2:300-699/3:1-299</sync-prioritymapping>
- 70: Text3: <sync-guid>{7552694F-D63E-42A1-AD43-B9834DD3BFEE}</sync-guid><sync-parentguid>{A28F628C-9632-4A42-82F4-B41391CDBFD8}</sync-parentguid><sync-checksum>-743152339</sync-checksum><sync-rootid>0</sync-rootid><sync-itemtype>0</sync-itemtype><sync-timestamp>2003 / Text5: -04-27 18:54:54</sync-timestamp><sync-itemid>70</sync-itemid><sync-prioritymapping>0:0-0/1:700-1000/2:300-699/3:1-299</sync-prioritymapping>
- 71: Text3: <sync-guid>{3FF4E49B-D961-4843-905E-8F2221DA6069}</sync-guid><sync-parentguid>{A28F628C-9632-4A42-82F4-B41391CDBFD8}</sync-parentguid><sync-checksum>293685356</sync-checksum><sync-rootid>0</sync-rootid><sync-itemtype>0</sync-itemtype><sync-timestamp>2003- / Text5: 04-27 18:54:54</sync-timestamp><sync-itemid>71</sync-itemid><sync-prioritymapping>0:0-0/1:700-1000/2:300-699/3:1-299</sync-prioritymapping>
- 72: Text3: <sync-guid>{3ADC0A5E-6A5F-437B-8715-B9E61EE74414}</sync-guid><sync-parentguid>{3FF4E49B-D961-4843-905E-8F2221DA6069}</sync-parentguid><sync-checksum>-2040281417</sync-checksum><sync-rootid>0</sync-rootid><sync-itemtype>0</sync-itemtype><sync-timestamp>200 / Text5: 3-04-27 18:54:55</sync-timestamp><sync-itemid>72</sync-itemid><sync-prioritymapping>0:0-0/1:700-1000/2:300-699/3:1-299</sync-prioritymapping>
- 73: Text3: <sync-guid>{A10EDE6E-6841-48D8-9763-3303BD9B2F0D}</sync-guid><sync-parentguid>{3FF4E49B-D961-4843-905E-8F2221DA6069}</sync-parentguid><sync-checksum>1180234627</sync-checksum><sync-rootid>0</sync-rootid><sync-itemtype>0</sync-itemtype><sync-timestamp>2003 / Text5: -04-27 18:54:55</sync-timestamp><sync-itemid>73</sync-itemid><sync-prioritymapping>0:0-0/1:700-1000/2:300-699/3:1-299</sync-prioritymapping>
- 74: Text3: <sync-guid>{2CEF89D5-3881-4511-9020-BD308921E061}</sync-guid><sync-parentguid>{3FF4E49B-D961-4843-905E-8F2221DA6069}</sync-parentguid><sync-checksum>-1820973790</sync-checksum><sync-rootid>0</sync-rootid><sync-itemtype>0</sync-itemtype><sync-timestamp>200 / Text5: 3-04-27 18:54:55</sync-timestamp><sync-itemid>74</sync-itemid><sync-prioritymapping>0:0-0/1:700-1000/2:300-699/3:1-299</sync-prioritymapping>
- 75: Text3: <sync-guid>{9F123A27-5D8E-4DA6-9592-B4CD01192658}</sync-guid><sync-parentguid>{3FF4E49B-D961-4843-905E-8F2221DA6069}</sync-parentguid><sync-checksum>-356231999</sync-checksum><sync-rootid>0</sync-rootid><sync-itemtype>0</sync-itemtype><sync-timestamp>2003 / Text5: -04-27 18:54:56</sync-timestamp><sync-itemid>75</sync-itemid><sync-prioritymapping>0:0-0/1:700-1000/2:300-699/3:1-299</sync-prioritymapping>
- 76: Text3: <sync-guid>{86DF9110-9170-4B24-BEAF-E6B7AC231C7B}</sync-guid><sync-parentguid>{3FF4E49B-D961-4843-905E-8F2221DA6069}</sync-parentguid><sync-checksum>223421848</sync-checksum><sync-rootid>0</sync-rootid><sync-itemtype>0</sync-itemtype><sync-timestamp>2003- / Text5: 04-27 18:54:56</sync-timestamp><sync-itemid>76</sync-itemid><sync-prioritymapping>0:0-0/1:700-1000/2:300-699/3:1-299</sync-prioritymapping>
- 77: Text3: <sync-guid>{BB67FDD3-1DD7-4A31-87E8-E194ED959BC8}</sync-guid><sync-parentguid>{3FF4E49B-D961-4843-905E-8F2221DA6069}</sync-parentguid><sync-checksum>-242940657</sync-checksum><sync-rootid>0</sync-rootid><sync-itemtype>0</sync-itemtype><sync-timestamp>2003 / Text5: -04-27 18:54:57</sync-timestamp><sync-itemid>77</sync-itemid><sync-prioritymapping>0:0-0/1:700-1000/2:300-699/3:1-299</sync-prioritymapping>
- 78: Text3: <sync-guid>{905BD7EE-6976-4C31-999D-F590DB784CED}</sync-guid><sync-parentguid>{A28F628C-9632-4A42-82F4-B41391CDBFD8}</sync-parentguid><sync-checksum>1394128564</sync-checksum><sync-rootid>0</sync-rootid><sync-itemtype>0</sync-itemtype><sync-timestamp>2003 / Text5: -04-27 18:54:57</sync-timestamp><sync-itemid>78</sync-itemid><sync-prioritymapping>0:0-0/1:700-1000/2:300-699/3:1-299</sync-prioritymapping>

| ID | WBS | Task | Type | Duration | Start | Finish | Predecessors | Baseline start | Baseline finish | Baseline duration | Total slack | Free slack | Resources | Work | Text4 |
| --- | --- | --- | --- | --- | --- | --- | --- | --- | --- | --- | --- | --- | --- | --- | --- |
| 79 | 4 | **Developing** |  | 81d | 2004-06-01 | 2004-09-22 |  | 2004-06-01 | 2004-09-22 | 81d | 0d |  | Development | 3141.04h | {94B267E3-512B-478B-9A86-0D8C26030299} |
| 80 | 4.1 | Update risk assessment |  | 1d | 2004-06-02 | 2004-06-02 | 78 | 2004-06-02 | 2004-06-02 | 1d | 79d |  | Program management [3%]; Product management [3%]; Development [3%]; Testing [3%]; Logistics management [3%]; User education [3%] | 1.44h | {D70C44B9-E3EF-423A-96EE-0724BD7476ED} |
| 81 | 4.2 | Equipment for development/proof of concept arrives | milestone | 0d | 2004-06-01 | 2004-06-01 | 78 | 2004-06-01 | 2004-06-01 | 0d | 0d |  | Logistics management |  | {2B2F3E5D-82DB-4817-882C-5BC40F279AD2} |
| 82 | 4.3 | Set up development environment/lab |  | 5d | 2004-06-02 | 2004-06-08 | 81 | 2004-06-02 | 2004-06-08 | 5d | 0d |  | Logistics management | 40h | {374A33C3-0C63-40DB-B505-909B6D507E0E} |
| 83 | 4.4 | **Internal Release #1** |  | 24d | 2004-06-02 | 2004-07-05 |  | 2004-06-02 | 2004-07-05 | 24d | 0d |  | Development | 691.6h | {D8325B1E-BB96-4D7F-B233-B2ADF1408445} |
| 84 | 4.4.1 | Develop target components |  | 9d | 2004-06-02 | 2004-06-14 | 78 | 2004-06-02 | 2004-06-14 | 9d | 15d |  | Development; Logistics management | 144h | {57AE9F25-3E15-447C-9006-643D7CCEEA86} |
| 85 | 4.4.2 | Test individual components |  | 5d | 2004-06-09 | 2004-06-15 | 82 | 2004-06-09 | 2004-06-15 | 5d | 0d |  | Testing; Development [25%] | 50h | {65C96B2B-78D4-4FD4-9330-38F1B18454E2} |
| 86 | 4.4.3 | Test integrated application |  | 6d | 2004-06-11 | 2004-06-18 | 85SS+2d | 2004-06-11 | 2004-06-18 | 6d | 0d |  | Testing; Development [25%] | 60h | {775FC47C-875B-4378-88D4-8C35CB33C0D8} |
| 87 | 4.4.4 | Develop performance enhancement materials |  | 4d | 2004-06-02 | 2004-06-07 | 78 | 2004-06-02 | 2004-06-07 | 4d | 8d | 0d | User education | 32h | {62CCDD62-3AC8-465B-8EDD-055CAD33FA87} |
| 88 | 4.4.5 | Test and review materials |  | 3d | 2004-06-08 | 2004-06-10 | 87 | 2004-06-08 | 2004-06-10 | 3d | 8d | 0d | Testing | 24h | {7B4CAC15-ABAB-43A7-B63F-FC5F6A631AF4} |
| 89 | 4.4.6 | Develop distribution procedures |  | 9d | 2004-06-11 | 2004-06-23 | 88 | 2004-06-11 | 2004-06-23 | 9d | 8d |  | Logistics management; Testing [30%] | 93.6h | {89E911DD-66DF-4E99-81C1-7C79C0A03A86} |
| 90 | 4.4.7 | Create distribution product |  | 2d | 2004-06-21 | 2004-06-22 | 85, 86 | 2004-06-21 | 2004-06-22 | 2d | 0d |  | Program management; Development; Testing; Logistics management; User education | 80h | {EE16FA24-BE52-415B-8A24-0AAD688ACC9B} |
| 91 | 4.4.8 | Distribute to appropriate parties |  | 1d | 2004-06-23 | 2004-06-23 | 90 | 2004-06-23 | 2004-06-23 | 1d | 0d |  | Program management; Logistics management | 16h | {6D10E595-2870-46E4-99D2-E9E2D43A9357} |
| 92 | 4.4.9 | Buffer |  | 8d | 2004-06-24 | 2004-07-05 | 91 | 2004-06-24 | 2004-07-05 | 8d | 0d |  |  |  | {1151D2D0-A677-48F8-B0E2-067E2DE89F64} |
| 93 | 4.5 | Internal release #1 complete | milestone | 0d | 2004-07-05 | 2004-07-05 | 83, 92 | 2004-07-05 | 2004-07-05 | 0d | 0d |  | Program management; Product management; Development; Testing; Logistics management |  | {AC74330B-43B3-4750-AAF2-6DE463D69D6B} |
| 94 | 4.6 | Review results from internal release |  | 2d | 2004-07-06 | 2004-07-07 | 93 | 2004-07-06 | 2004-07-07 | 2d | 0d |  |  |  | {2319026E-2976-4014-A788-FE366E65A8A2} |
| 95 | 4.7 | Perform post-release review |  | 1d | 2004-07-08 | 2004-07-08 | 94 | 2004-07-08 | 2004-07-08 | 1d | 0d |  |  |  | {F8FFC8AB-D0CE-48E4-B4B9-8CAA0FF905F8} |
| 96 | 4.8 | **Internal Release #n** |  | 24d | 2004-07-06 | 2004-08-06 |  | 2004-07-06 | 2004-08-06 | 24d | 0d |  | Development | 696h | {13DA5280-C876-40BD-B897-5FB10700E42C} |
| 97 | 4.8.1 | Develop target components |  | 10d | 2004-07-06 | 2004-07-19 | 93 | 2004-07-06 | 2004-07-19 | 10d | 3d |  | Development; Testing [50%]; Logistics management | 200h | {E024DBFF-6679-4B08-B53A-3A72A57650B1} |
| 98 | 4.8.2 | Test individual components |  | 4d | 2004-07-06 | 2004-07-09 | 93 | 2004-07-06 | 2004-07-09 | 4d | 9d |  | Testing | 32h | {DC406A73-9A6C-45E5-9041-1F5EEDC038D0} |
| 99 | 4.8.3 | Test integrated application |  | 5d | 2004-07-06 | 2004-07-12 | 93 | 2004-07-06 | 2004-07-12 | 5d | 18d |  | Testing | 40h | {7CF8BB36-F80A-43C8-976D-6B895F0CC242} |
| 100 | 4.8.4 | Develop performance enhancement materials |  | 4d | 2004-07-09 | 2004-07-14 | 95 | 2004-07-09 | 2004-07-14 | 4d | 0d |  | User education | 32h | {BD285268-772D-4E52-8773-E39EFDBE8C14} |
| 101 | 4.8.5 | Test and review materials |  | 3d | 2004-07-15 | 2004-07-19 | 100 | 2004-07-15 | 2004-07-19 | 3d | 0d |  | Testing | 24h | {ABDDB7DB-E711-4D76-B07B-1A9670B342D0} |
| 102 | 4.8.6 | Develop distribution procedures |  | 3d | 2004-07-20 | 2004-07-22 | 101 | 2004-07-20 | 2004-07-22 | 3d | 0d |  | Logistics management | 24h | {1E2F0328-3EE6-4CFA-8676-70D883BFE6CE} |
| 103 | 4.8.7 | Create distribution product |  | 4d | 2004-07-23 | 2004-07-28 | 98, 97, 102 | 2004-07-23 | 2004-07-28 | 4d | 0d |  | Development; Testing; Logistics management; User education | 128h | {C4F1DA72-6517-4A91-80E2-C6BF11104D74} |
| 104 | 4.8.8 | Buffer |  | 6d | 2004-07-29 | 2004-08-05 | 103 | 2004-07-29 | 2004-08-05 | 6d | 0d |  |  |  | {E18FF55F-763C-447A-8A58-F575C451AC79} |
| 105 | 4.8.9 | Distribute to appropriate parties |  | 1d | 2004-08-06 | 2004-08-06 | 99, 104 | 2004-08-06 | 2004-08-06 | 1d | 0d |  | Logistics management; Program management; Product management | 24h | {D1C6F801-7C50-45C0-A85A-667946424E31} |
| 106 | 4.9 | Internal release #n complete |  | 1d | 2004-08-09 | 2004-08-09 | 96, 105 | 2004-08-09 | 2004-08-09 | 1d | 0d |  | Program management; Product management; Development; Testing; Logistics management | 40h | {DCFAFA5E-8A9F-46DE-B91A-CD41F5FAC7CD} |
| 107 | 4.10 | Review results from internal release |  | 2d | 2004-08-10 | 2004-08-11 | 106 | 2004-08-10 | 2004-08-11 | 2d | 0d |  | Program management; Product management; Development; Testing; Logistics management; User education | 96h | {FB17337F-CEB9-491D-ABCC-19C8AA536951} |
| 108 | 4.11 | Functional specification freeze |  | 1d | 2004-08-12 | 2004-08-12 | 107 | 2004-08-12 | 2004-08-12 | 1d | 0d |  |  |  | {31969949-DE68-44B6-9932-575F276C9899} |
| 109 | 4.12 | Final feature development |  | 10d | 2004-08-13 | 2004-08-26 | 108 | 2004-08-13 | 2004-08-26 | 10d | 0d |  | Development; Testing [50%] | 120h | {4C5C5E0C-5DA3-48F3-BBC7-3529347804AB} |
| 110 | 4.13 | Final logistics development |  | 9d | 2004-08-13 | 2004-08-25 | 108 | 2004-08-13 | 2004-08-25 | 9d | 1d |  | Logistics management; Testing [50%] | 108h | {53B6759F-45EE-4AFD-9E4A-1F24BB48AA66} |
| 111 | 4.14 | Final performance support development |  | 5d | 2004-08-13 | 2004-08-19 | 108 | 2004-08-13 | 2004-08-19 | 5d | 5d |  | User education; Testing [50%] | 60h | {39AADC87-DF0B-48F8-A5DA-E4D47FA4AA13} |
| 112 | 4.15 | Feature complete | milestone | 0d | 2004-08-26 | 2004-08-26 | 109, 111, 110 | 2004-08-26 | 2004-08-26 | 0d | 0d |  |  |  | {6D347D5A-C21F-4985-B0F1-EEFC8FB8FBA3} |

Notes:
- 79: Text3: <sync-guid>{94B267E3-512B-478B-9A86-0D8C26030299}</sync-guid><sync-parentguid>{7132D1D4-D456-4D63-BFC8-4726AD2508E4}</sync-parentguid><sync-checksum>1407511092</sync-checksum><sync-rootid>0</sync-rootid><sync-itemtype>0</sync-itemtype><sync-timestamp>2003 / Text5: -04-27 18:54:57</sync-timestamp><sync-itemid>79</sync-itemid><sync-prioritymapping>0:0-0/1:700-1000/2:300-699/3:1-299</sync-prioritymapping>
- 80: This task should continue to occur throughout the Developing phase. One way to represent this is to do a paste link from the start date of task 81 to the start date of this task, and then do a paste link from the finish date of 122 to the finish date of this task. See the template Help file for more details. / Text3: <sync-guid>{D70C44B9-E3EF-423A-96EE-0724BD7476ED}</sync-guid><sync-parentguid>{94B267E3-512B-478B-9A86-0D8C26030299}</sync-parentguid><sync-checksum>1734772201</sync-checksum><sync-rootid>0</sync-rootid><sync-itemtype>0</sync-itemtype><sync-timestamp>2003 / Text5: -04-27 18:54:58</sync-timestamp><sync-itemid>80</sync-itemid><sync-prioritymapping>0:0-0/1:700-1000/2:300-699/3:1-299</sync-prioritymapping>
- 81: Text3: <sync-guid>{2B2F3E5D-82DB-4817-882C-5BC40F279AD2}</sync-guid><sync-parentguid>{94B267E3-512B-478B-9A86-0D8C26030299}</sync-parentguid><sync-checksum>1992518958</sync-checksum><sync-rootid>0</sync-rootid><sync-itemtype>0</sync-itemtype><sync-timestamp>2003 / Text5: -04-27 18:54:58</sync-timestamp><sync-itemid>81</sync-itemid><sync-prioritymapping>0:0-0/1:700-1000/2:300-699/3:1-299</sync-prioritymapping>
- 82: Text3: <sync-guid>{374A33C3-0C63-40DB-B505-909B6D507E0E}</sync-guid><sync-parentguid>{94B267E3-512B-478B-9A86-0D8C26030299}</sync-parentguid><sync-checksum>1080319193</sync-checksum><sync-rootid>0</sync-rootid><sync-itemtype>0</sync-itemtype><sync-timestamp>2003 / Text5: -04-27 18:54:59</sync-timestamp><sync-itemid>82</sync-itemid><sync-prioritymapping>0:0-0/1:700-1000/2:300-699/3:1-299</sync-prioritymapping>
- 83: Text3: <sync-guid>{D8325B1E-BB96-4D7F-B233-B2ADF1408445}</sync-guid><sync-parentguid>{94B267E3-512B-478B-9A86-0D8C26030299}</sync-parentguid><sync-checksum>-710048747</sync-checksum><sync-rootid>0</sync-rootid><sync-itemtype>0</sync-itemtype><sync-timestamp>2003 / Text5: -04-27 18:54:59</sync-timestamp><sync-itemid>83</sync-itemid><sync-prioritymapping>0:0-0/1:700-1000/2:300-699/3:1-299</sync-prioritymapping>
- 84: Text3: <sync-guid>{57AE9F25-3E15-447C-9006-643D7CCEEA86}</sync-guid><sync-parentguid>{D8325B1E-BB96-4D7F-B233-B2ADF1408445}</sync-parentguid><sync-checksum>107682512</sync-checksum><sync-rootid>0</sync-rootid><sync-itemtype>0</sync-itemtype><sync-timestamp>2003- / Text5: 04-27 18:54:59</sync-timestamp><sync-itemid>84</sync-itemid><sync-prioritymapping>0:0-0/1:700-1000/2:300-699/3:1-299</sync-prioritymapping>
- 85: Text3: <sync-guid>{65C96B2B-78D4-4FD4-9330-38F1B18454E2}</sync-guid><sync-parentguid>{D8325B1E-BB96-4D7F-B233-B2ADF1408445}</sync-parentguid><sync-checksum>-587199350</sync-checksum><sync-rootid>0</sync-rootid><sync-itemtype>0</sync-itemtype><sync-timestamp>2003 / Text5: -04-27 18:55:00</sync-timestamp><sync-itemid>85</sync-itemid><sync-prioritymapping>0:0-0/1:700-1000/2:300-699/3:1-299</sync-prioritymapping>
- 86: Text3: <sync-guid>{775FC47C-875B-4378-88D4-8C35CB33C0D8}</sync-guid><sync-parentguid>{D8325B1E-BB96-4D7F-B233-B2ADF1408445}</sync-parentguid><sync-checksum>-1934485643</sync-checksum><sync-rootid>0</sync-rootid><sync-itemtype>0</sync-itemtype><sync-timestamp>200 / Text5: 3-04-27 18:55:00</sync-timestamp><sync-itemid>86</sync-itemid><sync-prioritymapping>0:0-0/1:700-1000/2:300-699/3:1-299</sync-prioritymapping>
- 87: Text3: <sync-guid>{62CCDD62-3AC8-465B-8EDD-055CAD33FA87}</sync-guid><sync-parentguid>{D8325B1E-BB96-4D7F-B233-B2ADF1408445}</sync-parentguid><sync-checksum>-575562024</sync-checksum><sync-rootid>0</sync-rootid><sync-itemtype>0</sync-itemtype><sync-timestamp>2003 / Text5: -04-27 18:55:00</sync-timestamp><sync-itemid>87</sync-itemid><sync-prioritymapping>0:0-0/1:700-1000/2:300-699/3:1-299</sync-prioritymapping>
- 88: Text3: <sync-guid>{7B4CAC15-ABAB-43A7-B63F-FC5F6A631AF4}</sync-guid><sync-parentguid>{D8325B1E-BB96-4D7F-B233-B2ADF1408445}</sync-parentguid><sync-checksum>-1088833573</sync-checksum><sync-rootid>0</sync-rootid><sync-itemtype>0</sync-itemtype><sync-timestamp>200 / Text5: 3-04-27 18:55:01</sync-timestamp><sync-itemid>88</sync-itemid><sync-prioritymapping>0:0-0/1:700-1000/2:300-699/3:1-299</sync-prioritymapping>
- 89: Text3: <sync-guid>{89E911DD-66DF-4E99-81C1-7C79C0A03A86}</sync-guid><sync-parentguid>{D8325B1E-BB96-4D7F-B233-B2ADF1408445}</sync-parentguid><sync-checksum>1835312815</sync-checksum><sync-rootid>0</sync-rootid><sync-itemtype>0</sync-itemtype><sync-timestamp>2003 / Text5: -04-27 18:55:01</sync-timestamp><sync-itemid>89</sync-itemid><sync-prioritymapping>0:0-0/1:700-1000/2:300-699/3:1-299</sync-prioritymapping>
- 90: Text3: <sync-guid>{EE16FA24-BE52-415B-8A24-0AAD688ACC9B}</sync-guid><sync-parentguid>{D8325B1E-BB96-4D7F-B233-B2ADF1408445}</sync-parentguid><sync-checksum>-1098018990</sync-checksum><sync-rootid>0</sync-rootid><sync-itemtype>0</sync-itemtype><sync-timestamp>200 / Text5: 3-04-27 18:55:01</sync-timestamp><sync-itemid>90</sync-itemid><sync-prioritymapping>0:0-0/1:700-1000/2:300-699/3:1-299</sync-prioritymapping>
- 91: Text3: <sync-guid>{6D10E595-2870-46E4-99D2-E9E2D43A9357}</sync-guid><sync-parentguid>{D8325B1E-BB96-4D7F-B233-B2ADF1408445}</sync-parentguid><sync-checksum>49554019</sync-checksum><sync-rootid>0</sync-rootid><sync-itemtype>0</sync-itemtype><sync-timestamp>2003-0 / Text5: 4-27 18:55:02</sync-timestamp><sync-itemid>91</sync-itemid><sync-prioritymapping>0:0-0/1:700-1000/2:300-699/3:1-299</sync-prioritymapping>
- 92: Text3: <sync-guid>{1151D2D0-A677-48F8-B0E2-067E2DE89F64}</sync-guid><sync-parentguid>{D8325B1E-BB96-4D7F-B233-B2ADF1408445}</sync-parentguid><sync-checksum>1704166173</sync-checksum><sync-rootid>0</sync-rootid><sync-itemtype>0</sync-itemtype><sync-timestamp>2003 / Text5: -04-27 18:55:02</sync-timestamp><sync-itemid>92</sync-itemid><sync-prioritymapping>0:0-0/1:700-1000/2:300-699/3:1-299</sync-prioritymapping>
- 93: Text3: <sync-guid>{AC74330B-43B3-4750-AAF2-6DE463D69D6B}</sync-guid><sync-parentguid>{94B267E3-512B-478B-9A86-0D8C26030299}</sync-parentguid><sync-checksum>154498958</sync-checksum><sync-rootid>0</sync-rootid><sync-itemtype>0</sync-itemtype><sync-timestamp>2003- / Text5: 04-27 18:55:02</sync-timestamp><sync-itemid>93</sync-itemid><sync-prioritymapping>0:0-0/1:700-1000/2:300-699/3:1-299</sync-prioritymapping>
- 94: Text3: <sync-guid>{2319026E-2976-4014-A788-FE366E65A8A2}</sync-guid><sync-parentguid>{94B267E3-512B-478B-9A86-0D8C26030299}</sync-parentguid><sync-checksum>-2042471586</sync-checksum><sync-rootid>0</sync-rootid><sync-itemtype>0</sync-itemtype><sync-timestamp>200 / Text5: 3-04-27 18:55:03</sync-timestamp><sync-itemid>94</sync-itemid><sync-prioritymapping>0:0-0/1:700-1000/2:300-699/3:1-299</sync-prioritymapping>
- 95: Text3: <sync-guid>{F8FFC8AB-D0CE-48E4-B4B9-8CAA0FF905F8}</sync-guid><sync-parentguid>{94B267E3-512B-478B-9A86-0D8C26030299}</sync-parentguid><sync-checksum>-1197624603</sync-checksum><sync-rootid>0</sync-rootid><sync-itemtype>0</sync-itemtype><sync-timestamp>200 / Text5: 3-04-27 18:55:03</sync-timestamp><sync-itemid>95</sync-itemid><sync-prioritymapping>0:0-0/1:700-1000/2:300-699/3:1-299</sync-prioritymapping>
- 96: Text3: <sync-guid>{13DA5280-C876-40BD-B897-5FB10700E42C}</sync-guid><sync-parentguid>{94B267E3-512B-478B-9A86-0D8C26030299}</sync-parentguid><sync-checksum>553901387</sync-checksum><sync-rootid>0</sync-rootid><sync-itemtype>0</sync-itemtype><sync-timestamp>2003- / Text5: 04-27 18:55:03</sync-timestamp><sync-itemid>96</sync-itemid><sync-prioritymapping>0:0-0/1:700-1000/2:300-699/3:1-299</sync-prioritymapping>
- 97: Text3: <sync-guid>{E024DBFF-6679-4B08-B53A-3A72A57650B1}</sync-guid><sync-parentguid>{13DA5280-C876-40BD-B897-5FB10700E42C}</sync-parentguid><sync-checksum>-1538841781</sync-checksum><sync-rootid>0</sync-rootid><sync-itemtype>0</sync-itemtype><sync-timestamp>200 / Text5: 3-04-27 18:55:04</sync-timestamp><sync-itemid>97</sync-itemid><sync-prioritymapping>0:0-0/1:700-1000/2:300-699/3:1-299</sync-prioritymapping>
- 98: Text3: <sync-guid>{DC406A73-9A6C-45E5-9041-1F5EEDC038D0}</sync-guid><sync-parentguid>{13DA5280-C876-40BD-B897-5FB10700E42C}</sync-parentguid><sync-checksum>-926011623</sync-checksum><sync-rootid>0</sync-rootid><sync-itemtype>0</sync-itemtype><sync-timestamp>2003 / Text5: -04-27 18:55:04</sync-timestamp><sync-itemid>98</sync-itemid><sync-prioritymapping>0:0-0/1:700-1000/2:300-699/3:1-299</sync-prioritymapping>
- 99: Text3: <sync-guid>{7CF8BB36-F80A-43C8-976D-6B895F0CC242}</sync-guid><sync-parentguid>{13DA5280-C876-40BD-B897-5FB10700E42C}</sync-parentguid><sync-checksum>-369704856</sync-checksum><sync-rootid>0</sync-rootid><sync-itemtype>0</sync-itemtype><sync-timestamp>2003 / Text5: -04-27 18:55:04</sync-timestamp><sync-itemid>99</sync-itemid><sync-prioritymapping>0:0-0/1:700-1000/2:300-699/3:1-299</sync-prioritymapping>
- 100: Text3: <sync-guid>{BD285268-772D-4E52-8773-E39EFDBE8C14}</sync-guid><sync-parentguid>{13DA5280-C876-40BD-B897-5FB10700E42C}</sync-parentguid><sync-checksum>-1115696665</sync-checksum><sync-rootid>0</sync-rootid><sync-itemtype>0</sync-itemtype><sync-timestamp>200 / Text5: 3-04-27 18:55:05</sync-timestamp><sync-itemid>100</sync-itemid><sync-prioritymapping>0:0-0/1:700-1000/2:300-699/3:1-299</sync-prioritymapping>
- 101: Text3: <sync-guid>{ABDDB7DB-E711-4D76-B07B-1A9670B342D0}</sync-guid><sync-parentguid>{13DA5280-C876-40BD-B897-5FB10700E42C}</sync-parentguid><sync-checksum>639660796</sync-checksum><sync-rootid>0</sync-rootid><sync-itemtype>0</sync-itemtype><sync-timestamp>2003- / Text5: 04-27 18:55:05</sync-timestamp><sync-itemid>101</sync-itemid><sync-prioritymapping>0:0-0/1:700-1000/2:300-699/3:1-299</sync-prioritymapping>
- 102: Text3: <sync-guid>{1E2F0328-3EE6-4CFA-8676-70D883BFE6CE}</sync-guid><sync-parentguid>{13DA5280-C876-40BD-B897-5FB10700E42C}</sync-parentguid><sync-checksum>-504007367</sync-checksum><sync-rootid>0</sync-rootid><sync-itemtype>0</sync-itemtype><sync-timestamp>2003 / Text5: -04-27 18:55:06</sync-timestamp><sync-itemid>102</sync-itemid><sync-prioritymapping>0:0-0/1:700-1000/2:300-699/3:1-299</sync-prioritymapping>
- 103: Text3: <sync-guid>{C4F1DA72-6517-4A91-80E2-C6BF11104D74}</sync-guid><sync-parentguid>{13DA5280-C876-40BD-B897-5FB10700E42C}</sync-parentguid><sync-checksum>1479552413</sync-checksum><sync-rootid>0</sync-rootid><sync-itemtype>0</sync-itemtype><sync-timestamp>2003 / Text5: -04-27 18:55:06</sync-timestamp><sync-itemid>103</sync-itemid><sync-prioritymapping>0:0-0/1:700-1000/2:300-699/3:1-299</sync-prioritymapping>
- 104: Text3: <sync-guid>{E18FF55F-763C-447A-8A58-F575C451AC79}</sync-guid><sync-parentguid>{13DA5280-C876-40BD-B897-5FB10700E42C}</sync-parentguid><sync-checksum>147985869</sync-checksum><sync-rootid>0</sync-rootid><sync-itemtype>0</sync-itemtype><sync-timestamp>2003- / Text5: 04-27 18:55:06</sync-timestamp><sync-itemid>104</sync-itemid><sync-prioritymapping>0:0-0/1:700-1000/2:300-699/3:1-299</sync-prioritymapping>
- 105: Text3: <sync-guid>{D1C6F801-7C50-45C0-A85A-667946424E31}</sync-guid><sync-parentguid>{13DA5280-C876-40BD-B897-5FB10700E42C}</sync-parentguid><sync-checksum>267551037</sync-checksum><sync-rootid>0</sync-rootid><sync-itemtype>0</sync-itemtype><sync-timestamp>2003- / Text5: 04-27 18:55:07</sync-timestamp><sync-itemid>105</sync-itemid><sync-prioritymapping>0:0-0/1:700-1000/2:300-699/3:1-299</sync-prioritymapping>
- 106: Text3: <sync-guid>{DCFAFA5E-8A9F-46DE-B91A-CD41F5FAC7CD}</sync-guid><sync-parentguid>{94B267E3-512B-478B-9A86-0D8C26030299}</sync-parentguid><sync-checksum>1207136285</sync-checksum><sync-rootid>0</sync-rootid><sync-itemtype>0</sync-itemtype><sync-timestamp>2003 / Text5: -04-27 18:55:07</sync-timestamp><sync-itemid>106</sync-itemid><sync-prioritymapping>0:0-0/1:700-1000/2:300-699/3:1-299</sync-prioritymapping>
- 107: Text3: <sync-guid>{FB17337F-CEB9-491D-ABCC-19C8AA536951}</sync-guid><sync-parentguid>{94B267E3-512B-478B-9A86-0D8C26030299}</sync-parentguid><sync-checksum>640196922</sync-checksum><sync-rootid>0</sync-rootid><sync-itemtype>0</sync-itemtype><sync-timestamp>2003- / Text5: 04-27 18:55:08</sync-timestamp><sync-itemid>107</sync-itemid><sync-prioritymapping>0:0-0/1:700-1000/2:300-699/3:1-299</sync-prioritymapping>
- 108: Text3: <sync-guid>{31969949-DE68-44B6-9932-575F276C9899}</sync-guid><sync-parentguid>{94B267E3-512B-478B-9A86-0D8C26030299}</sync-parentguid><sync-checksum>-26713907</sync-checksum><sync-rootid>0</sync-rootid><sync-itemtype>0</sync-itemtype><sync-timestamp>2003- / Text5: 04-27 18:55:08</sync-timestamp><sync-itemid>108</sync-itemid><sync-prioritymapping>0:0-0/1:700-1000/2:300-699/3:1-299</sync-prioritymapping>
- 109: Text3: <sync-guid>{4C5C5E0C-5DA3-48F3-BBC7-3529347804AB}</sync-guid><sync-parentguid>{94B267E3-512B-478B-9A86-0D8C26030299}</sync-parentguid><sync-checksum>2081872408</sync-checksum><sync-rootid>0</sync-rootid><sync-itemtype>0</sync-itemtype><sync-timestamp>2003 / Text5: -04-27 18:55:08</sync-timestamp><sync-itemid>109</sync-itemid><sync-prioritymapping>0:0-0/1:700-1000/2:300-699/3:1-299</sync-prioritymapping>
- 110: Text3: <sync-guid>{53B6759F-45EE-4AFD-9E4A-1F24BB48AA66}</sync-guid><sync-parentguid>{94B267E3-512B-478B-9A86-0D8C26030299}</sync-parentguid><sync-checksum>-908203274</sync-checksum><sync-rootid>0</sync-rootid><sync-itemtype>0</sync-itemtype><sync-timestamp>2003 / Text5: -04-27 18:55:09</sync-timestamp><sync-itemid>110</sync-itemid><sync-prioritymapping>0:0-0/1:700-1000/2:300-699/3:1-299</sync-prioritymapping>
- 111: Text3: <sync-guid>{39AADC87-DF0B-48F8-A5DA-E4D47FA4AA13}</sync-guid><sync-parentguid>{94B267E3-512B-478B-9A86-0D8C26030299}</sync-parentguid><sync-checksum>-1166550735</sync-checksum><sync-rootid>0</sync-rootid><sync-itemtype>0</sync-itemtype><sync-timestamp>200 / Text5: 3-04-27 18:55:09</sync-timestamp><sync-itemid>111</sync-itemid><sync-prioritymapping>0:0-0/1:700-1000/2:300-699/3:1-299</sync-prioritymapping>
- 112: Text3: <sync-guid>{6D347D5A-C21F-4985-B0F1-EEFC8FB8FBA3}</sync-guid><sync-parentguid>{94B267E3-512B-478B-9A86-0D8C26030299}</sync-parentguid><sync-checksum>7321316</sync-checksum><sync-rootid>0</sync-rootid><sync-itemtype>0</sync-itemtype><sync-timestamp>2003-04 / Text5: -27 18:55:09</sync-timestamp><sync-itemid>112</sync-itemid><sync-prioritymapping>0:0-0/1:700-1000/2:300-699/3:1-299</sync-prioritymapping>

| ID | WBS | Task | Type | Duration | Start | Finish | Predecessors | Baseline start | Baseline finish | Baseline duration | Total slack | Resources | Work | Text4 |
| --- | --- | --- | --- | --- | --- | --- | --- | --- | --- | --- | --- | --- | --- | --- |
| 113 | 4.16 | **Update Plans and Schedules** |  | 13d | 2004-08-27 | 2004-09-14 |  | 2004-08-27 | 2004-09-14 | 13d | 0d | Program management | 360h | {0F9FC53F-6320-479A-9AEA-0B2E9D5C2F7C} |
| 114 | 4.16.1 | Update development plan |  | 4d | 2004-08-27 | 2004-09-01 | 112 | 2004-08-27 | 2004-09-01 | 4d | 0d | Development | 32h | {73C10BFA-342A-4D5F-A811-3240EBFA1DFA} |
| 115 | 4.16.2 | Update testing plan |  | 3d | 2004-08-27 | 2004-08-31 | 114SS | 2004-08-27 | 2004-08-31 | 3d | 10d | Testing | 24h | {46F74A8E-655B-46E2-8E9D-01E6EA3F6CF8} |
| 116 | 4.16.3 | Update logistics plan |  | 13d | 2004-08-27 | 2004-09-14 | 114SS | 2004-08-27 | 2004-09-14 | 13d | 0d | Logistics management | 104h | {796F59EE-F340-44B6-9745-6A21C91E664B} |
| 117 | 4.16.4 | Update program management plan |  | 3d | 2004-08-27 | 2004-08-31 | 114SS | 2004-08-27 | 2004-08-31 | 3d | 10d | Program management | 24h | {74B7C393-E38E-47C5-8DFE-09658E7E1FB0} |
| 118 | 4.16.5 | Update product management plan |  | 3d | 2004-08-27 | 2004-08-31 | 114SS | 2004-08-27 | 2004-08-31 | 3d | 10d | Product management | 24h | {EAE3E4EF-9DAE-4E74-9A3C-86E6FB54685B} |
| 119 | 4.16.6 | Update user education plan |  | 6d | 2004-08-27 | 2004-09-03 | 114SS | 2004-08-27 | 2004-09-03 | 6d | 7d | User education | 48h | {56F8E6A1-93A7-4991-9BFD-26090230C05F} |
| 120 | 4.17 | Buffer |  | 3d | 2004-09-15 | 2004-09-17 | 114, 115, 116, 119, 117, 118 | 2004-09-15 | 2004-09-17 | 3d | 0d | Program management; Product management; Development; Testing; Logistics management; User education | 144h | {097E55F9-85B3-4186-9FDB-AB467AF58156} |
| 121 | 4.18 | Perform milestone review |  | 2d | 2004-09-20 | 2004-09-21 | 120 | 2004-09-20 | 2004-09-21 | 2d | 0d | Program management; Product management; Development; Testing; Logistics management; User education | 96h | {3DFE4A29-2FDE-4688-B4B3-9A70BBB83B3B} |
| 122 | 4.19 | Scope complete |  | 1d | 2004-09-22 | 2004-09-22 | 113, 121, 80 | 2004-09-22 | 2004-09-22 | 1d | 0d | Program management; Product management; Development; Testing; Logistics management | 40h | {6ECA2F16-E54E-4C43-A821-50514B97985B} |
| 123 | 5 | **Stabilizing** |  | 73d | 2004-09-23 | 2005-01-03 |  | 2004-09-23 | 2005-01-03 | 73d | 0d | Logistics management | 1684h | {0E318D91-D9A2-4CA2-97AD-AD3B96668B18} |
| 124 | 5.1 | Update risk assessment |  | 1d | 2004-09-23 | 2004-09-23 | 122, 103 | 2004-09-23 | 2004-09-23 | 1d | 71d | Program management [10%]; Product management [10%]; Development [10%]; Testing [10%]; Logistics management [10%]; User education [10%]; Support organization [10%]; Customer [10%] | 6.4h | {500961C1-0A67-4C39-A47E-B9FA4F5FD05B} |
| 125 | 5.2 | **Beta Release 1** |  | 32d | 2004-09-23 | 2004-11-05 |  | 2004-09-23 | 2004-11-05 | 32d | 0d |  | 784h | {301CC7DA-5744-4F80-B8C4-503C90642BF3} |
| 126 | 5.2.1 | Develop beta plan |  | 3d | 2004-09-23 | 2004-09-27 | 103, 122 | 2004-09-23 | 2004-09-27 | 3d | 0d | Program management; Logistics management | 48h | {1D4DE9DF-9D10-4EC6-A242-E4F86061F5E7} |
| 127 | 5.2.2 | Solicit and select users |  | 2d | 2004-09-28 | 2004-09-29 | 126 | 2004-09-28 | 2004-09-29 | 2d | 0d | Product management; Program management | 32h | {845D1412-B861-4FD3-BF3B-7B05360BB2C8} |
| 128 | 5.2.3 | Prepare beta package |  | 8d | 2004-09-28 | 2004-10-07 | 120, 127SS | 2004-09-28 | 2004-10-07 | 8d | 0d | Program management; Development; Logistics management; Testing | 256h | {A4C23D12-BFF6-4A73-96D1-795EE2442AB2} |
| 129 | 5.2.4 | Begin beta | milestone | 0d | 2004-10-07 | 2004-10-07 | 128 | 2004-10-07 | 2004-10-07 | 0d | 0d |  |  | {30528F6B-504C-4EFF-BC3E-F2F5C11B9B28} |
| 130 | 5.2.5 | Provide beta support |  | 8d | 2004-10-08 | 2004-10-19 | 129 | 2004-10-08 | 2004-10-19 | 8d | 0d | Development; Logistics management | 128h | {52145FD6-8806-4DBC-B1C0-C681D21F42AC} |
| 131 | 5.2.6 | Gather user feedback |  | 7d | 2004-10-20 | 2004-10-28 | 130 | 2004-10-20 | 2004-10-28 | 7d | 0d |  |  | {D1A10ADD-A700-4283-B031-E2F6F322678C} |
| 132 | 5.2.7 | Close beta support | milestone | 0d | 2004-10-28 | 2004-10-28 | 131 | 2004-10-28 | 2004-10-28 | 0d | 0d |  |  | {9B8F1ABF-44CA-4107-93FD-6FC7CD651A2D} |
| 133 | 5.2.8 | Fix bugs |  | 10d | 2004-10-25 | 2004-11-05 | 132FS-4d | 2004-10-25 | 2004-11-05 | 10d | 0d | Development; Program management; Logistics management; User education | 320h | {855709BA-2417-4CC8-A8C2-2F2581C90FE9} |
| 134 | 5.2.9 | End beta | milestone | 0d | 2004-11-05 | 2004-11-05 | 130, 133 | 2004-11-05 | 2004-11-05 | 0d | 0d |  |  | {02EEE8BA-6B0F-4AE2-B2A0-8F3FEBE13DAB} |
| 135 | 5.3 | Beta release n |  | 1d | 2004-11-08 | 2004-11-08 | 134 | 2004-11-08 | 2004-11-08 | 1d | 0d |  |  | {38EC9C96-D300-460A-BC6F-A1B85428FDE1} |
| 136 | 5.4 | Fix bugs |  | 10d | 2004-11-09 | 2004-11-22 | 135 | 2004-11-09 | 2004-11-22 | 10d | 0d | Development; Testing; Program management [25%] | 180h | {B8CB4AC6-C45B-4C2B-98F2-DBFC89BBDC7F} |
| 137 | 5.5 | Bug convergence |  | 1d | 2004-11-23 | 2004-11-23 | 136 | 2004-11-23 | 2004-11-23 | 1d | 0d |  |  | {0B35BF0E-4723-48F5-A4A9-DEFB9542AD93} |
| 138 | 5.6 | Fix high priority bugs |  | 10d | 2004-11-24 | 2004-12-07 | 137 | 2004-11-24 | 2004-12-07 | 10d | 0d |  |  | {F32A3154-5D2D-471C-9843-CB9AD87C4DF3} |
| 139 | 5.7 | Zero bug release | milestone | 0d | 2004-12-07 | 2004-12-07 | 138 | 2004-12-07 | 2004-12-07 | 0d | 0d | Program management |  | {DD85BCEA-C2B4-467C-81DE-086343BAB16F} |
| 140 | 5.8 | Perform final bug triage |  | 5d | 2004-12-08 | 2004-12-14 | 139 | 2004-12-08 | 2004-12-14 | 5d | 0d |  |  | {0F220176-A052-4563-8D62-E00B4F2C2BFF} |

Notes:
- 113: Text3: <sync-guid>{0F9FC53F-6320-479A-9AEA-0B2E9D5C2F7C}</sync-guid><sync-parentguid>{94B267E3-512B-478B-9A86-0D8C26030299}</sync-parentguid><sync-checksum>684925751</sync-checksum><sync-rootid>0</sync-rootid><sync-itemtype>0</sync-itemtype><sync-timestamp>2003- / Text5: 04-27 18:55:10</sync-timestamp><sync-itemid>113</sync-itemid><sync-prioritymapping>0:0-0/1:700-1000/2:300-699/3:1-299</sync-prioritymapping>
- 114: Text3: <sync-guid>{73C10BFA-342A-4D5F-A811-3240EBFA1DFA}</sync-guid><sync-parentguid>{0F9FC53F-6320-479A-9AEA-0B2E9D5C2F7C}</sync-parentguid><sync-checksum>1558721535</sync-checksum><sync-rootid>0</sync-rootid><sync-itemtype>0</sync-itemtype><sync-timestamp>2003 / Text5: -04-27 18:55:10</sync-timestamp><sync-itemid>114</sync-itemid><sync-prioritymapping>0:0-0/1:700-1000/2:300-699/3:1-299</sync-prioritymapping>
- 115: Text3: <sync-guid>{46F74A8E-655B-46E2-8E9D-01E6EA3F6CF8}</sync-guid><sync-parentguid>{0F9FC53F-6320-479A-9AEA-0B2E9D5C2F7C}</sync-parentguid><sync-checksum>-1022792903</sync-checksum><sync-rootid>0</sync-rootid><sync-itemtype>0</sync-itemtype><sync-timestamp>200 / Text5: 3-04-27 18:55:11</sync-timestamp><sync-itemid>115</sync-itemid><sync-prioritymapping>0:0-0/1:700-1000/2:300-699/3:1-299</sync-prioritymapping>
- 116: Text3: <sync-guid>{796F59EE-F340-44B6-9745-6A21C91E664B}</sync-guid><sync-parentguid>{0F9FC53F-6320-479A-9AEA-0B2E9D5C2F7C}</sync-parentguid><sync-checksum>1146182946</sync-checksum><sync-rootid>0</sync-rootid><sync-itemtype>0</sync-itemtype><sync-timestamp>2003 / Text5: -04-27 18:55:11</sync-timestamp><sync-itemid>116</sync-itemid><sync-prioritymapping>0:0-0/1:700-1000/2:300-699/3:1-299</sync-prioritymapping>
- 117: Text3: <sync-guid>{74B7C393-E38E-47C5-8DFE-09658E7E1FB0}</sync-guid><sync-parentguid>{0F9FC53F-6320-479A-9AEA-0B2E9D5C2F7C}</sync-parentguid><sync-checksum>-1712660592</sync-checksum><sync-rootid>0</sync-rootid><sync-itemtype>0</sync-itemtype><sync-timestamp>200 / Text5: 3-04-27 18:55:11</sync-timestamp><sync-itemid>117</sync-itemid><sync-prioritymapping>0:0-0/1:700-1000/2:300-699/3:1-299</sync-prioritymapping>
- 118: Text3: <sync-guid>{EAE3E4EF-9DAE-4E74-9A3C-86E6FB54685B}</sync-guid><sync-parentguid>{0F9FC53F-6320-479A-9AEA-0B2E9D5C2F7C}</sync-parentguid><sync-checksum>1149864234</sync-checksum><sync-rootid>0</sync-rootid><sync-itemtype>0</sync-itemtype><sync-timestamp>2003 / Text5: -04-27 18:55:12</sync-timestamp><sync-itemid>118</sync-itemid><sync-prioritymapping>0:0-0/1:700-1000/2:300-699/3:1-299</sync-prioritymapping>
- 119: Text3: <sync-guid>{56F8E6A1-93A7-4991-9BFD-26090230C05F}</sync-guid><sync-parentguid>{0F9FC53F-6320-479A-9AEA-0B2E9D5C2F7C}</sync-parentguid><sync-checksum>680068939</sync-checksum><sync-rootid>0</sync-rootid><sync-itemtype>0</sync-itemtype><sync-timestamp>2003- / Text5: 04-27 18:55:12</sync-timestamp><sync-itemid>119</sync-itemid><sync-prioritymapping>0:0-0/1:700-1000/2:300-699/3:1-299</sync-prioritymapping>
- 120: Text3: <sync-guid>{097E55F9-85B3-4186-9FDB-AB467AF58156}</sync-guid><sync-parentguid>{94B267E3-512B-478B-9A86-0D8C26030299}</sync-parentguid><sync-checksum>78088903</sync-checksum><sync-rootid>0</sync-rootid><sync-itemtype>0</sync-itemtype><sync-timestamp>2003-0 / Text5: 4-27 18:55:12</sync-timestamp><sync-itemid>120</sync-itemid><sync-prioritymapping>0:0-0/1:700-1000/2:300-699/3:1-299</sync-prioritymapping>
- 121: Text3: <sync-guid>{3DFE4A29-2FDE-4688-B4B3-9A70BBB83B3B}</sync-guid><sync-parentguid>{94B267E3-512B-478B-9A86-0D8C26030299}</sync-parentguid><sync-checksum>574327564</sync-checksum><sync-rootid>0</sync-rootid><sync-itemtype>0</sync-itemtype><sync-timestamp>2003- / Text5: 04-27 18:55:13</sync-timestamp><sync-itemid>121</sync-itemid><sync-prioritymapping>0:0-0/1:700-1000/2:300-699/3:1-299</sync-prioritymapping>
- 122: Text3: <sync-guid>{6ECA2F16-E54E-4C43-A821-50514B97985B}</sync-guid><sync-parentguid>{94B267E3-512B-478B-9A86-0D8C26030299}</sync-parentguid><sync-checksum>-1954998425</sync-checksum><sync-rootid>0</sync-rootid><sync-itemtype>0</sync-itemtype><sync-timestamp>200 / Text5: 3-04-27 18:55:13</sync-timestamp><sync-itemid>122</sync-itemid><sync-prioritymapping>0:0-0/1:700-1000/2:300-699/3:1-299</sync-prioritymapping>
- 123: Text3: <sync-guid>{0E318D91-D9A2-4CA2-97AD-AD3B96668B18}</sync-guid><sync-parentguid>{7132D1D4-D456-4D63-BFC8-4726AD2508E4}</sync-parentguid><sync-checksum>1809324658</sync-checksum><sync-rootid>0</sync-rootid><sync-itemtype>0</sync-itemtype><sync-timestamp>2003 / Text5: -04-27 18:55:14</sync-timestamp><sync-itemid>123</sync-itemid><sync-prioritymapping>0:0-0/1:700-1000/2:300-699/3:1-299</sync-prioritymapping>
- 124: This task should continue to occur throughout the Stabilizing phase. One way to represent this is to do a paste link from the start date of task 126 to the start date of this task, and then do a paste link from the finish date of 147 to the finish date of this task. See the template Help file for more details. / Text3: <sync-guid>{500961C1-0A67-4C39-A47E-B9FA4F5FD05B}</sync-guid><sync-parentguid>{0E318D91-D9A2-4CA2-97AD-AD3B96668B18}</sync-parentguid><sync-checksum>1231852261</sync-checksum><sync-rootid>0</sync-rootid><sync-itemtype>0</sync-itemtype><sync-timestamp>2003 / Text5: -04-27 18:55:14</sync-timestamp><sync-itemid>124</sync-itemid><sync-prioritymapping>0:0-0/1:700-1000/2:300-699/3:1-299</sync-prioritymapping>
- 125: Text3: <sync-guid>{301CC7DA-5744-4F80-B8C4-503C90642BF3}</sync-guid><sync-parentguid>{0E318D91-D9A2-4CA2-97AD-AD3B96668B18}</sync-parentguid><sync-checksum>-1936027704</sync-checksum><sync-rootid>0</sync-rootid><sync-itemtype>0</sync-itemtype><sync-timestamp>200 / Text5: 3-04-27 18:55:14</sync-timestamp><sync-itemid>125</sync-itemid><sync-prioritymapping>0:0-0/1:700-1000/2:300-699/3:1-299</sync-prioritymapping>
- 126: Text3: <sync-guid>{1D4DE9DF-9D10-4EC6-A242-E4F86061F5E7}</sync-guid><sync-parentguid>{301CC7DA-5744-4F80-B8C4-503C90642BF3}</sync-parentguid><sync-checksum>-1543522193</sync-checksum><sync-rootid>0</sync-rootid><sync-itemtype>0</sync-itemtype><sync-timestamp>200 / Text5: 3-04-27 18:55:15</sync-timestamp><sync-itemid>126</sync-itemid><sync-prioritymapping>0:0-0/1:700-1000/2:300-699/3:1-299</sync-prioritymapping>
- 127: Text3: <sync-guid>{845D1412-B861-4FD3-BF3B-7B05360BB2C8}</sync-guid><sync-parentguid>{301CC7DA-5744-4F80-B8C4-503C90642BF3}</sync-parentguid><sync-checksum>1088312481</sync-checksum><sync-rootid>0</sync-rootid><sync-itemtype>0</sync-itemtype><sync-timestamp>2003 / Text5: -04-27 18:55:15</sync-timestamp><sync-itemid>127</sync-itemid><sync-prioritymapping>0:0-0/1:700-1000/2:300-699/3:1-299</sync-prioritymapping>
- 128: Text3: <sync-guid>{A4C23D12-BFF6-4A73-96D1-795EE2442AB2}</sync-guid><sync-parentguid>{301CC7DA-5744-4F80-B8C4-503C90642BF3}</sync-parentguid><sync-checksum>1453816037</sync-checksum><sync-rootid>0</sync-rootid><sync-itemtype>0</sync-itemtype><sync-timestamp>2003 / Text5: -04-27 18:55:16</sync-timestamp><sync-itemid>128</sync-itemid><sync-prioritymapping>0:0-0/1:700-1000/2:300-699/3:1-299</sync-prioritymapping>
- 129: Text3: <sync-guid>{30528F6B-504C-4EFF-BC3E-F2F5C11B9B28}</sync-guid><sync-parentguid>{301CC7DA-5744-4F80-B8C4-503C90642BF3}</sync-parentguid><sync-checksum>208216959</sync-checksum><sync-rootid>0</sync-rootid><sync-itemtype>0</sync-itemtype><sync-timestamp>2003- / Text5: 04-27 18:55:16</sync-timestamp><sync-itemid>129</sync-itemid><sync-prioritymapping>0:0-0/1:700-1000/2:300-699/3:1-299</sync-prioritymapping>
- 130: Text3: <sync-guid>{52145FD6-8806-4DBC-B1C0-C681D21F42AC}</sync-guid><sync-parentguid>{301CC7DA-5744-4F80-B8C4-503C90642BF3}</sync-parentguid><sync-checksum>-1431074453</sync-checksum><sync-rootid>0</sync-rootid><sync-itemtype>0</sync-itemtype><sync-timestamp>200 / Text5: 3-04-27 18:55:16</sync-timestamp><sync-itemid>130</sync-itemid><sync-prioritymapping>0:0-0/1:700-1000/2:300-699/3:1-299</sync-prioritymapping>
- 131: Text3: <sync-guid>{D1A10ADD-A700-4283-B031-E2F6F322678C}</sync-guid><sync-parentguid>{301CC7DA-5744-4F80-B8C4-503C90642BF3}</sync-parentguid><sync-checksum>-1918290475</sync-checksum><sync-rootid>0</sync-rootid><sync-itemtype>0</sync-itemtype><sync-timestamp>200 / Text5: 3-04-27 18:55:17</sync-timestamp><sync-itemid>131</sync-itemid><sync-prioritymapping>0:0-0/1:700-1000/2:300-699/3:1-299</sync-prioritymapping>
- 132: Text3: <sync-guid>{9B8F1ABF-44CA-4107-93FD-6FC7CD651A2D}</sync-guid><sync-parentguid>{301CC7DA-5744-4F80-B8C4-503C90642BF3}</sync-parentguid><sync-checksum>146468703</sync-checksum><sync-rootid>0</sync-rootid><sync-itemtype>0</sync-itemtype><sync-timestamp>2003- / Text5: 04-27 18:55:17</sync-timestamp><sync-itemid>132</sync-itemid><sync-prioritymapping>0:0-0/1:700-1000/2:300-699/3:1-299</sync-prioritymapping>
- 133: Text3: <sync-guid>{855709BA-2417-4CC8-A8C2-2F2581C90FE9}</sync-guid><sync-parentguid>{301CC7DA-5744-4F80-B8C4-503C90642BF3}</sync-parentguid><sync-checksum>-361047196</sync-checksum><sync-rootid>0</sync-rootid><sync-itemtype>0</sync-itemtype><sync-timestamp>2003 / Text5: -04-27 18:55:17</sync-timestamp><sync-itemid>133</sync-itemid><sync-prioritymapping>0:0-0/1:700-1000/2:300-699/3:1-299</sync-prioritymapping>
- 134: Text3: <sync-guid>{02EEE8BA-6B0F-4AE2-B2A0-8F3FEBE13DAB}</sync-guid><sync-parentguid>{301CC7DA-5744-4F80-B8C4-503C90642BF3}</sync-parentguid><sync-checksum>-1746447959</sync-checksum><sync-rootid>0</sync-rootid><sync-itemtype>0</sync-itemtype><sync-timestamp>200 / Text5: 3-04-27 18:55:18</sync-timestamp><sync-itemid>134</sync-itemid><sync-prioritymapping>0:0-0/1:700-1000/2:300-699/3:1-299</sync-prioritymapping>
- 135: Text3: <sync-guid>{38EC9C96-D300-460A-BC6F-A1B85428FDE1}</sync-guid><sync-parentguid>{0E318D91-D9A2-4CA2-97AD-AD3B96668B18}</sync-parentguid><sync-checksum>-1453928294</sync-checksum><sync-rootid>0</sync-rootid><sync-itemtype>0</sync-itemtype><sync-timestamp>200 / Text5: 3-04-27 18:55:18</sync-timestamp><sync-itemid>135</sync-itemid><sync-prioritymapping>0:0-0/1:700-1000/2:300-699/3:1-299</sync-prioritymapping>
- 136: Text3: <sync-guid>{B8CB4AC6-C45B-4C2B-98F2-DBFC89BBDC7F}</sync-guid><sync-parentguid>{0E318D91-D9A2-4CA2-97AD-AD3B96668B18}</sync-parentguid><sync-checksum>55794531</sync-checksum><sync-rootid>0</sync-rootid><sync-itemtype>0</sync-itemtype><sync-timestamp>2003-0 / Text5: 4-27 18:55:18</sync-timestamp><sync-itemid>136</sync-itemid><sync-prioritymapping>0:0-0/1:700-1000/2:300-699/3:1-299</sync-prioritymapping>
- 137: Text3: <sync-guid>{0B35BF0E-4723-48F5-A4A9-DEFB9542AD93}</sync-guid><sync-parentguid>{0E318D91-D9A2-4CA2-97AD-AD3B96668B18}</sync-parentguid><sync-checksum>-2118572999</sync-checksum><sync-rootid>0</sync-rootid><sync-itemtype>0</sync-itemtype><sync-timestamp>200 / Text5: 3-04-27 18:55:19</sync-timestamp><sync-itemid>137</sync-itemid><sync-prioritymapping>0:0-0/1:700-1000/2:300-699/3:1-299</sync-prioritymapping>
- 138: Text3: <sync-guid>{F32A3154-5D2D-471C-9843-CB9AD87C4DF3}</sync-guid><sync-parentguid>{0E318D91-D9A2-4CA2-97AD-AD3B96668B18}</sync-parentguid><sync-checksum>-147761398</sync-checksum><sync-rootid>0</sync-rootid><sync-itemtype>0</sync-itemtype><sync-timestamp>2003 / Text5: -04-27 18:55:19</sync-timestamp><sync-itemid>138</sync-itemid><sync-prioritymapping>0:0-0/1:700-1000/2:300-699/3:1-299</sync-prioritymapping>
- 139: Text3: <sync-guid>{DD85BCEA-C2B4-467C-81DE-086343BAB16F}</sync-guid><sync-parentguid>{0E318D91-D9A2-4CA2-97AD-AD3B96668B18}</sync-parentguid><sync-checksum>-960644012</sync-checksum><sync-rootid>0</sync-rootid><sync-itemtype>0</sync-itemtype><sync-timestamp>2003 / Text5: -04-27 18:55:19</sync-timestamp><sync-itemid>139</sync-itemid><sync-prioritymapping>0:0-0/1:700-1000/2:300-699/3:1-299</sync-prioritymapping>
- 140: Text3: <sync-guid>{0F220176-A052-4563-8D62-E00B4F2C2BFF}</sync-guid><sync-parentguid>{0E318D91-D9A2-4CA2-97AD-AD3B96668B18}</sync-parentguid><sync-checksum>1017643973</sync-checksum><sync-rootid>0</sync-rootid><sync-itemtype>0</sync-itemtype><sync-timestamp>2003 / Text5: -04-27 18:55:20</sync-timestamp><sync-itemid>140</sync-itemid><sync-prioritymapping>0:0-0/1:700-1000/2:300-699/3:1-299</sync-prioritymapping>

| ID | WBS | Task | Type | Duration | Start | Finish | Predecessors | Baseline start | Baseline finish | Baseline duration | Total slack | Resources | Work | Text4 |
| --- | --- | --- | --- | --- | --- | --- | --- | --- | --- | --- | --- | --- | --- | --- |
| 141 | 5.9 | **Release Candidate 1** |  | 7d | 2004-12-15 | 2004-12-23 | 140 | 2004-12-15 | 2004-12-23 | 7d | 0d |  | 129.6h | {04CAFD21-F0FC-4A94-9B9D-9379BC097D1B} |
| 142 | 5.9.1 | Development team evaluation |  | 2d | 2004-12-15 | 2004-12-16 |  | 2004-12-15 | 2004-12-16 | 2d | 0d | Development; Logistics management [80%]; Program management [50%]; Product management [30%]; User education [50%]; Testing [75%] | 61.6h | {BD579BAE-62EB-4BC6-83BA-016320939E62} |
| 143 | 5.9.2 | Customer/user evaluation |  | 2d | 2004-12-17 | 2004-12-20 | 142 | 2004-12-17 | 2004-12-20 | 2d | 0d | Product management; User education | 32h | {BEDD85C5-F240-4D4F-9FC0-71AF0B249E5C} |
| 144 | 5.9.3 | Support evaluation |  | 3d | 2004-12-21 | 2004-12-23 | 143 | 2004-12-21 | 2004-12-23 | 3d | 0d | Support organization; Logistics management [25%]; Program management [25%] | 36h | {81B6D89D-076E-4975-8C5B-E4FC007793CA} |
| 145 | 5.10 | Release candidate n |  | 6d | 2004-12-24 | 2004-12-31 | 144 | 2004-12-24 | 2004-12-31 | 6d | 0d |  |  | {3EBD0C9F-3204-487E-8ECD-4667685E971B} |
| 146 | 5.11 | Golden release | milestone | 0d | 2004-12-31 | 2004-12-31 | 145 | 2004-12-31 | 2004-12-31 | 0d | 0d |  |  | {8955A765-1036-490F-975C-E4C88313E512} |
| 147 | 5.12 | Release |  | 1d | 2005-01-03 | 2005-01-03 | 146, 124 | 2005-01-03 | 2005-01-03 | 1d | 0d |  |  | {19396BDE-15B4-4607-971D-2BB84A02AC79} |
| 148 | 6 | Post project review |  | 2d | 2005-02-15 | 2005-02-16 | 147FS+30d | 2005-02-15 | 2005-02-16 | 2d | 0d |  |  | {BECA3B62-6A67-44D5-BBB2-2E446A778194} |

Notes:
- 141: Text3: <sync-guid>{04CAFD21-F0FC-4A94-9B9D-9379BC097D1B}</sync-guid><sync-parentguid>{0E318D91-D9A2-4CA2-97AD-AD3B96668B18}</sync-parentguid><sync-checksum>1856341044</sync-checksum><sync-rootid>0</sync-rootid><sync-itemtype>0</sync-itemtype><sync-timestamp>2003 / Text5: -04-27 18:55:20</sync-timestamp><sync-itemid>141</sync-itemid><sync-prioritymapping>0:0-0/1:700-1000/2:300-699/3:1-299</sync-prioritymapping>
- 142: Text3: <sync-guid>{BD579BAE-62EB-4BC6-83BA-016320939E62}</sync-guid><sync-parentguid>{04CAFD21-F0FC-4A94-9B9D-9379BC097D1B}</sync-parentguid><sync-checksum>1434094884</sync-checksum><sync-rootid>0</sync-rootid><sync-itemtype>0</sync-itemtype><sync-timestamp>2003 / Text5: -04-27 18:55:20</sync-timestamp><sync-itemid>142</sync-itemid><sync-prioritymapping>0:0-0/1:700-1000/2:300-699/3:1-299</sync-prioritymapping>
- 143: Text3: <sync-guid>{BEDD85C5-F240-4D4F-9FC0-71AF0B249E5C}</sync-guid><sync-parentguid>{04CAFD21-F0FC-4A94-9B9D-9379BC097D1B}</sync-parentguid><sync-checksum>-1019549136</sync-checksum><sync-rootid>0</sync-rootid><sync-itemtype>0</sync-itemtype><sync-timestamp>200 / Text5: 3-04-27 18:55:21</sync-timestamp><sync-itemid>143</sync-itemid><sync-prioritymapping>0:0-0/1:700-1000/2:300-699/3:1-299</sync-prioritymapping>
- 144: Text3: <sync-guid>{81B6D89D-076E-4975-8C5B-E4FC007793CA}</sync-guid><sync-parentguid>{04CAFD21-F0FC-4A94-9B9D-9379BC097D1B}</sync-parentguid><sync-checksum>-463497417</sync-checksum><sync-rootid>0</sync-rootid><sync-itemtype>0</sync-itemtype><sync-timestamp>2003 / Text5: -04-27 18:55:21</sync-timestamp><sync-itemid>144</sync-itemid><sync-prioritymapping>0:0-0/1:700-1000/2:300-699/3:1-299</sync-prioritymapping>
- 145: Text3: <sync-guid>{3EBD0C9F-3204-487E-8ECD-4667685E971B}</sync-guid><sync-parentguid>{0E318D91-D9A2-4CA2-97AD-AD3B96668B18}</sync-parentguid><sync-checksum>1935158913</sync-checksum><sync-rootid>0</sync-rootid><sync-itemtype>0</sync-itemtype><sync-timestamp>2003 / Text5: -04-27 18:55:22</sync-timestamp><sync-itemid>145</sync-itemid><sync-prioritymapping>0:0-0/1:700-1000/2:300-699/3:1-299</sync-prioritymapping>
- 146: Text3: <sync-guid>{8955A765-1036-490F-975C-E4C88313E512}</sync-guid><sync-parentguid>{0E318D91-D9A2-4CA2-97AD-AD3B96668B18}</sync-parentguid><sync-checksum>1467430415</sync-checksum><sync-rootid>0</sync-rootid><sync-itemtype>0</sync-itemtype><sync-timestamp>2003 / Text5: -04-27 18:55:22</sync-timestamp><sync-itemid>146</sync-itemid><sync-prioritymapping>0:0-0/1:700-1000/2:300-699/3:1-299</sync-prioritymapping>
- 147: Text3: <sync-guid>{19396BDE-15B4-4607-971D-2BB84A02AC79}</sync-guid><sync-parentguid>{0E318D91-D9A2-4CA2-97AD-AD3B96668B18}</sync-parentguid><sync-checksum>-1699644210</sync-checksum><sync-rootid>0</sync-rootid><sync-itemtype>0</sync-itemtype><sync-timestamp>200 / Text5: 3-04-27 18:55:22</sync-timestamp><sync-itemid>147</sync-itemid><sync-prioritymapping>0:0-0/1:700-1000/2:300-699/3:1-299</sync-prioritymapping>
- 148: Text3: <sync-guid>{BECA3B62-6A67-44D5-BBB2-2E446A778194}</sync-guid><sync-parentguid>{7132D1D4-D456-4D63-BFC8-4726AD2508E4}</sync-parentguid><sync-checksum>-1497839004</sync-checksum><sync-rootid>0</sync-rootid><sync-itemtype>0</sync-itemtype><sync-timestamp>200 / Text5: 3-04-27 18:55:22</sync-timestamp><sync-itemid>148</sync-itemid><sync-prioritymapping>0:0-0/1:700-1000/2:300-699/3:1-299</sync-prioritymapping>
